# PLAZO TOTAL A2 TRAMO II-LACRAMARCA

Schedule from Primavera P6, 2023-11-28 to 2024-10-26, data date 2023-11-27.

## Calendars

- EFECTIVOS REV.03: Mon-Sat 07:00-16:00; Sun off. Exceptions (off unless hours are given): 2023-12-08 to 2023-12-09, 2023-12-25, 2024-01-01, 2024-03-28 to 2024-03-29, 2024-04-06 08:00-16:00, 2024-05-01, 2024-06-29, 2024-07-29, 2024-08-30, 2024-10-08.
- DIAS CALENDARIOS REV.03: Mon-Sun 07:00-16:00.

## Resources

| Resource | Group | Notes |
| --- | --- | --- |
| Camión grua | labor | ï»¿ |
| CAPATAZ | labor | ï»¿ |
| OPERARIO | labor | ï»¿ |
| PEON | labor | ï»¿ |
| Camión Cisterna 4x2 400 HP Agua (5000 gal) | labor | ï»¿ |
| CUADRADOR/VIGÍA | labor | ï»¿ |
| Motoniveladora 185 HP | labor | ï»¿ |
| Retroexcavador 58 HP | labor | ï»¿ |
| Rodillo Vib. Liso Autopropulsado 135 HP 12 TM | labor | ï»¿ |
| Camión baranda 3 TON | labor | ï»¿ |
| Tractor S/Orugas (D6T) - 180 HP | labor | ï»¿ |
| Camión Volquete (15 m3) | labor | ï»¿ |
| Excavadora Sobre Oruga 260 HP | labor | ï»¿ |
| TOPOGRAFO | labor | ï»¿ |
| OFICIAL | labor | ï»¿ |
| CARGADOR SOBRE LLANTAS DE 200-250 HP | labor | ï»¿ |
| Excavadora + Martillo hidraúlico | labor | ï»¿ |
| Camión Volquete Roquero (15 m3) | labor | ï»¿ |
| AYUDANTE DE NIVELADOR | labor | ï»¿ |
| AYUDANTE DE TOPOGRAFO | labor | ï»¿ |
| OP. NIVELADOR | labor | ï»¿ |

## Schedule

| ID | WBS | Activity | Type | Duration | Start | Finish | Predecessors | Total float | Free float | Calendar | Resources |
| --- | --- | --- | --- | --- | --- | --- | --- | --- | --- | --- | --- |
|  | 1 | **HITOS** |  |  | 2023-11-28 | 2023-12-14 |  |  |  |  |  |
| A |  | KICK OF MEETING (KMO) | milestone | 0d | 2023-11-28 | 2023-11-28 |  | 0d |  | DIAS CALENDARIOS REV.03 |  |
| B |  | MOVILIZACIÓN DE EQUIPOS |  | 16d | 2023-11-29 | 2023-12-14 | A SS+1d | 0d |  | DIAS CALENDARIOS REV.03 |  |
| C |  | INICIO DE MOVILIZACIÓN DE EQUIPOS | milestone | 0d | 2023-11-29 | 2023-11-29 | A SS+1d | 15d |  | DIAS CALENDARIOS REV.03 |  |
|  | 2 | **INICIO DE PLAZO CONTRACTUAL - FIN DE OBRA** |  |  | 2023-12-14 | 2024-10-26 |  |  |  |  |  |
| D |  | INICIO DE PLAZO CONTRACTUAL - ACCESO AL SITIO | milestone | 0d | 2023-12-14 | 2023-12-14 | B SS+15d, C SS | 0d |  | DIAS CALENDARIOS REV.03 |  |
| E |  | INICIO DE EXCAVACIÓN | milestone | 0d | 2024-01-03 | 2024-01-03 | D SS+20d | 0d |  | DIAS CALENDARIOS REV.03 |  |
| G |  | INICIO DE DIQUE MARGEN IZQUIERDO | milestone | 0d | 2024-01-03 | 2024-01-03 | 1.04.03.01 SS, F SS-10d | 297.41d | 187.61d | DIAS CALENDARIOS REV.03 |  |
| F |  | INICIO DE RELLENO DE DIQUE | milestone | 0d | 2024-01-13 | 2024-01-13 | 1.04.03.42 SS | 287.81d | 0d | DIAS CALENDARIOS REV.03 |  |
| H |  | INICIO DE DIQUE MARGEN DERECHO | milestone | 0d | 2024-03-01 | 2024-03-01 | 1.04.03.05 SS | 239.41d | 178.61d | DIAS CALENDARIOS REV.03 |  |
| L |  | FIN DE DIQUE MARGEN IZQUIERDO | milestone | 0d | 2024-07-08 | 2024-07-08 | 1.04.03.77 FF, G SF | 109.8d |  | DIAS CALENDARIOS REV.03 |  |
| M |  | FIN DE DIQUE MARGEN DERECHO | milestone | 0d | 2024-08-26 | 2024-08-26 | 1.04.03.82 FF, H SF | 60.8d |  | DIAS CALENDARIOS REV.03 |  |
| I |  | INICIO DE TOMAS | milestone | 0d | 2024-08-27 | 2024-08-27 | 1.04.03.103 SS | 60.3d | 15.5d | DIAS CALENDARIOS REV.03 |  |
| J |  | INICIO DE RETORNOS | milestone | 0d | 2024-08-28 | 2024-08-28 | 1.04.03.113 SS | 59.3d | 16.5d | DIAS CALENDARIOS REV.03 |  |
| K |  | INICIO DE LIBERACIÓN PREDIAL | milestone | 0d | 2024-08-29 | 2024-08-29 | 1.04.03.93 SS | 58.3d | 51.5d | DIAS CALENDARIOS REV.03 |  |
| N |  | FIN DE TOMAS | milestone | 0d | 2024-09-11 | 2024-09-11 | 1.04.03.82.1 FF, I SF | 44.8d |  | DIAS CALENDARIOS REV.03 |  |
| O |  | FIN DE RETORNOS | milestone | 0d | 2024-09-13 | 2024-09-13 | 1.04.03.82.11 FF, J SF | 42.8d |  | DIAS CALENDARIOS REV.03 |  |
| P |  | FIN DE LIBERACIÓN PREDIAL | milestone | 0d | 2024-10-19 | 2024-10-19 | 1.04.03.82.21 FF, K SF | 6.8d |  | DIAS CALENDARIOS REV.03 |  |
| Q |  | FIN DE PLAZO CONTRACTUAL - CULMINACIÓN DE OBRA | milestone | 0d | 2024-10-26 | 2024-10-26 | 01.06.05 FF+0.4d | 0d |  | DIAS CALENDARIOS REV.03 |  |
|  | 3 | **CONSTRUCCIÓN SUB PROYECTO A2 TRAMO II-RÍO LACRAMARCA** |  |  | 2023-12-14 | 2024-10-26 |  |  |  |  |  |
|  | 1 | **DEFENSAS RIBEREÑAS** |  |  | 2023-12-14 | 2024-10-26 |  |  |  |  |  |
|  | 1 | **OBRAS PRELIMINARES** |  |  | 2023-12-14 | 2024-08-10 |  |  |  |  |  |
| 1.01.02 |  | INSTALACIONES PROVISIONALES PARA LA OBRA |  | 5d | 2023-12-14 | 2023-12-19 | D SS | 63.61d | 0d |  | Camión grua [216 h]; CAPATAZ [80 h]; OPERARIO [480 h]; PEON [800 h] |
| 1.01.03 |  | MANTENIMIENTO DE TRÁNSITO Y SEGURIDAD VIAL |  | 199.5d | 2023-12-14 | 2024-08-10 | D SS | 63.8d |  |  | Camión Cisterna 4x2 400 HP Agua (5000 gal) [1560 h]; CAPATAZ [2080 h]; CUADRADOR/VIGÍA [4160 h]; Motoniveladora 185 HP [1560 h]; Retroexcavador 58 HP [825 h]; Rodillo Vib. Liso Autopropulsado 135 HP 12 TM [1560 h] |

| ID | WBS | Activity | Duration | Start | Finish | Predecessors | Total float | Free float | Resources |
| --- | --- | --- | --- | --- | --- | --- | --- | --- | --- |
|  | 2 | **TRABAJOS PRELIMINARES** |  | 2023-12-14 | 2024-08-10 |  |  |  |  |
| 01.02.1 |  | TOPOGRAFÍA Y GEOREFERENCIACIÓN | 199.69d | 2023-12-14 | 2024-08-10 | 1.01.02 SS | 63.61d |  | AYUDANTE DE NIVELADOR [6676.8 h]; AYUDANTE DE TOPOGRAFO [6677 h]; TOPOGRAFO [4451.2 h]; OP. NIVELADOR [2225.6 h] |
|  | 3 | **OBRAS DE DESVÍO TEMPORAL** |  | 2023-12-21 | 2024-03-26 |  |  |  |  |
|  | 1 | **SUBPROYECTO A2-TRAMO II** |  | 2023-12-21 | 2024-03-26 |  |  |  |  |
| 1.03.01.01 |  | CONFORMACIÓN DE DESVIO EN CAUCE DE RÍO-LI | 32d | 2023-12-21 | 2024-01-29 | 1.01.02 FS+1d | 98.88d | 0d | CAPATAZ [510 h]; CUADRADOR/VIGÍA [510 h]; Excavadora Sobre Oruga 260 HP [251 h]; OPERARIO [510 h]; PEON [1012 h]; Tractor S/Orugas (D6T) - 180 HP [510 h] |
| 1.03.01.02 |  | RELLENO NO ESTRUCTURAL CON MATERIAL PROPIO-LI | 43d | 2023-12-28 | 2024-02-16 | 1.03.01.01 SS+5d | 209.3d |  | Camión Cisterna 4x2 400 HP Agua (5000 gal) [335 h]; CAPATAZ [168 h]; OPERARIO [335 h]; PEON [678 h]; Rodillo Vib. Liso Autopropulsado 135 HP 12 TM [335 h]; Tractor S/Orugas (D6T) - 180 HP [335 h] |
| 1.03.01.03 |  | CONFORMACIÓN DE DESVIO EN CAUCE DE RÍO-LD | 32d | 2024-01-30 | 2024-03-06 | 1.03.01.01 | 176.3d | 0d | CAPATAZ [510 h]; CUADRADOR/VIGÍA [510 h]; Excavadora Sobre Oruga 260 HP [251 h]; OPERARIO [510 h]; PEON [1012 h]; Tractor S/Orugas (D6T) - 180 HP [510 h] |
| 1.03.01.04 |  | RELLENO NO ESTRUCTURAL CON MATERIAL PROPIO-LD | 43d | 2024-02-06 | 2024-03-26 | 1.03.01.03 SS+6d | 176.3d |  | Camión Cisterna 4x2 400 HP Agua (5000 gal) [335 h]; CAPATAZ [168 h]; OPERARIO [335 h]; PEON [678 h]; Rodillo Vib. Liso Autopropulsado 135 HP 12 TM [335 h]; Tractor S/Orugas (D6T) - 180 HP [335 h] |
|  | 4 | **OBRAS EXTERIORES** |  | 2023-12-23 | 2024-10-19 |  |  |  |  |
|  | 1 | **PREPARACIÓN DEL SITIO** |  | 2023-12-23 | 2024-03-25 |  |  |  |  |
|  | 4 | **SUBPROYECTO A2-TRAMO II** |  | 2023-12-23 | 2024-03-25 |  |  |  |  |
|  | 1 | **DESCOLMATACIÓN DE CAUCE Y OBRAS AUXILIARES** |  | 2023-12-23 | 2024-03-25 |  |  |  |  |
| 1.04.01.01 |  | DESBROCE Y LIMPIEZA EN ZONA NO BOSCOSA | 58d | 2023-12-23 | 2024-03-01 | 1.03.01.01 SS+2d | 98.88d | 0d | Camión Volquete (15 m3) [438.65 h]; Excavadora Sobre Oruga 260 HP [243.69 h]; OPERARIO [438.65 h]; PEON [2729.36 h]; Tractor S/Orugas (D6T) - 180 HP [438.65 h] |
| 1.04.01.1 |  | DESCOLMATACIÓN DE CAUCE NATURAL DEL RÍO LACRAMARCA | 78d | 2023-12-23 | 2024-03-25 | 1.04.01.01 SS | 98.88d | 0d | CUADRADOR/VIGÍA [2363.61 h]; Excavadora Sobre Oruga 260 HP [3545.41 h]; PEON [4727.22 h]; Tractor S/Orugas (D6T) - 180 HP [2363.61 h]; CAPATAZ [236.36 h] |
|  | 2 | **CAMINOS PROVISIONALES** |  | 2023-12-30 | 2024-02-01 |  |  |  |  |
|  | 1 | **SUBPROYECTO A2-TRAMO II** |  | 2023-12-30 | 2024-02-01 |  |  |  |  |
|  | 1 | **MEJORAMIENTO DE VÍAS EXISTENTES** |  | 2023-12-30 | 2024-02-01 |  |  |  |  |
|  | 1 | **MOVIMIENTO DE TIERRAS** |  | 2023-12-30 | 2024-01-25 |  |  |  |  |
| 1.04.02.01 |  | ROCE Y LIMPIEZA DE MALEZA | 2d | 2023-12-30 | 2024-01-02 | 1.04.01.01 SS+5d | 222.3d | 0d | Camión baranda 3 TON [31 h]; CAPATAZ [15 h]; CUADRADOR/VIGÍA [14.93 h]; PEON [61 h]; Retroexcavador 58 HP [15 h]; Tractor S/Orugas (D6T) - 180 HP [15 h] |
| 1.04.02.02 |  | REHABILITACIÓN DE VÍAS EXISTENTES | 20d | 2024-01-03 | 2024-01-25 | 1.04.02.01 | 222.3d | 0d | CAPATAZ [619 h]; CUADRADOR/VIGÍA [1238 h]; PEON [1238 h]; Tractor S/Orugas (D6T) - 180 HP [619 h]; OFICIAL [619 h]; Camión Volquete (15 m3) [1238 h]; Camión Cisterna 4x2 400 HP Agua (5000 gal) [619 h]; OPERARIO [619 h] |
| 1.04.02.03 |  | CONFORMACIÓN DE TERRAPLENES EN CAMINO | 1d | 2024-01-25 | 2024-01-25 | 1.04.02.02 FS-1d | 222.3d | 0d | CAPATAZ [2 h]; OPERARIO [2 h]; OFICIAL [2 h]; PEON [7 h]; Excavadora Sobre Oruga 260 HP [2 h]; Rodillo Vib. Liso Autopropulsado 135 HP 12 TM [2 h]; Motoniveladora 185 HP [2 h]; Camión Cisterna 4x2 400 HP Agua (5000 gal) [2 h] |
|  | 2 | **REPOSICIÓN DE ESTRUCTURAS** |  | 2024-01-26 | 2024-01-29 |  |  |  |  |
| 1.04.02.04 |  | REPOSICIÓN DE PASE DE AGUA TUBERÍA HDPE Ø=24" | 1d | 2024-01-26 | 2024-01-26 | 1.04.02.03 | 222.3d | 0d | CAPATAZ [0.04 h]; OPERARIO [1 h]; PEON [1.49 h]; Retroexcavador 58 HP [0.37 h] |
| 1.04.02.05 |  | REPOSICIÓN DE PASE DE AGUA TUBERÍA HDPE Ø=18" | 0.53d | 2024-01-27 | 2024-01-27 | 1.04.02.04 | 222.3d | 0d | CAPATAZ; OPERARIO [0.53 h]; PEON [1 h]; Retroexcavador 58 HP [0.27 h] |
| 1.04.02.06 |  | REPARACIÓN DE CONCRETO | 1d | 2024-01-29 | 2024-01-29 | 1.04.02.05 FS+0.47d | 222.3d | 0d | OPERARIO [1 h] |

| ID | WBS | Activity | Duration | Start | Finish | Predecessors | Total float | Free float | Resources |
| --- | --- | --- | --- | --- | --- | --- | --- | --- | --- |
|  | 3 | **CABEZAL DE ENTRADA Y SALIDA** |  | 2024-01-30 | 2024-02-01 |  |  |  |  |
| 1.04.02.08 |  | ENCOFRADO Y DESENCOFRADO NORMAL | 2d | 2024-01-30 | 2024-01-31 | 1.04.02.06 | 222.3d | 0d | CAPATAZ [5.84 h]; OPERARIO [11.67 h]; PEON [11.67 h] |
| 1.04.02.07 |  | CONCRETO 175 Kg/Cm2 | 1d | 2024-02-01 | 2024-02-01 | 1.04.02.08 | 222.3d |  | CAPATAZ [0.03 h]; OPERARIO [0.58 h]; OFICIAL [0.29 h]; PEON [1.16 h] |
|  | 3 | **DIQUES DE TIERRA COMPACTADA CON ENROCADO** |  | 2024-01-03 | 2024-10-19 |  |  |  |  |
|  | 1 | **SUBPROYECTO A2-TRAMO II** |  | 2024-01-03 | 2024-10-19 |  |  |  |  |
|  | 1 | **EXCAVACIÓN EN TERRENO NATURAL CON EQUIPO** |  | 2024-01-03 | 2024-09-03 |  |  |  |  |
| 1.04.03.01 |  | EXCAVACIÓN EN TERRENO NATURAL CON EQUIPO A2-I-05 | 5d | 2024-01-03 | 2024-01-08 | E SS | 0d |  | CAPATAZ [6.42 h]; PEON [64.23 h]; Tractor S/Orugas (D6T) - 180 HP [64 h]; Excavadora Sobre Oruga 260 HP [64.23 h] |
| 1.04.03.02 |  | EXCAVACIÓN EN TERRENO NATURAL CON EQUIPO A2-I-04 | 34d | 2024-01-09 | 2024-02-16 | 1.04.03.01 | 0d |  | CAPATAZ [53.42 h]; PEON [534 h]; Tractor S/Orugas (D6T) - 180 HP [534 h]; Excavadora Sobre Oruga 260 HP [534.18 h] |
| 1.04.03.03 |  | EXCAVACIÓN EN TERRENO NATURAL CON EQUIPO A2-I-07 | 16.5d | 2024-02-02 | 2024-02-21 | 1.04.03.02 FS-13d | 0d |  | CAPATAZ [29.19 h]; PEON [291.88 h]; Tractor S/Orugas (D6T) - 180 HP [291.88 h]; Excavadora Sobre Oruga 260 HP [291.88 h] |
| 1.04.03.04 |  | EXCAVACIÓN EN TERRENO NATURAL CON EQUIPO A2-I-06 | 11d | 2024-02-22 | 2024-03-05 | 1.04.03.03 FS+0.5d | 0d |  | CAPATAZ [16.78 h]; PEON [167.77 h]; Tractor S/Orugas (D6T) - 180 HP [167.77 h]; Excavadora Sobre Oruga 260 HP [167.77 h] |
| 1.04.03.05 |  | EXCAVACIÓN EN TERRENO NATURAL CON EQUIPO A2-D-03 | 35.5d | 2024-03-01 | 2024-04-13 | 1.04.03.04 FS-4d | 0d |  | CAPATAZ [56.91 h]; PEON [569.1 h]; Tractor S/Orugas (D6T) - 180 HP [569.1 h]; Excavadora Sobre Oruga 260 HP [569.1 h] |
| 1.04.03.06 |  | EXCAVACIÓN EN TERRENO NATURAL CON EQUIPO A2-D-06 | 25.5d | 2024-04-06 | 2024-05-07 | 1.04.03.05 FS-6.5d | 0d |  | CAPATAZ [45.71 h]; PEON [457.13 h]; Tractor S/Orugas (D6T) - 180 HP [457.13 h]; Excavadora Sobre Oruga 260 HP [457.13 h] |
| 1.04.03.07 |  | EXCAVACIÓN EN TERRENO NATURAL CON EQUIPO A2-D-05 | 11.5d | 2024-05-08 | 2024-05-21 | 1.04.03.06 FS+0.5d | 0d |  | CAPATAZ [18.91 h]; PEON [189.09 h]; Tractor S/Orugas (D6T) - 180 HP [189.09 h]; Excavadora Sobre Oruga 260 HP [189.09 h] |
| 1.04.03.08 |  | EXCAVACIÓN EN TERRENO NATURAL CON EQUIPO A2-D-04 | 2.5d | 2024-05-22 | 2024-05-24 | 1.04.03.07 FS+0.5d | 111.8d | 0d | CAPATAZ [4.12 h]; PEON [41.23 h]; Tractor S/Orugas (D6T) - 180 HP [41.23 h]; Excavadora Sobre Oruga 260 HP [41.23 h] |
| 1.04.03.94 |  | EXCAVACIÓN EN TERRENO NATURAL CON EQUIPO RAMPAS | 1.5d | 2024-05-25 | 2024-05-27 | 1.04.03.08 FS+0.5d | 111.8d | 0d | CAPATAZ [0.51 h]; PEON [1 h]; Tractor S/Orugas (D6T) - 180 HP [1 h]; Excavadora Sobre Oruga 260 HP [1 h] |
| 1.04.03.103 |  | EXCAVACIÓN EN TERRENO NATURAL CON EQUIPO TOMAS | 0.5d | 2024-08-27 | 2024-08-27 | 1.04.03.82 FS+0.5d | 0d |  | CAPATAZ [18.91 h]; PEON [189.09 h]; Tractor S/Orugas (D6T) - 180 HP [189.09 h]; Excavadora Sobre Oruga 260 HP [189.09 h] |
| 1.04.03.113 |  | EXCAVACIÓN EN TERRENO NATURAL CON EQUIPO RETORNOS | 0.5d | 2024-08-28 | 2024-08-28 | 1.04.03.103 FS+0.5d | 0d |  | CAPATAZ [1 h]; PEON [1 h]; Tractor S/Orugas (D6T) - 180 HP [1 h]; Excavadora Sobre Oruga 260 HP [1 h] |
| 1.04.03.93 |  | EXCAVACIÓN EN TERRENO NATURAL CON EQUIPO LIBERACIÓN PREDIAL | 3.5d | 2024-08-29 | 2024-09-03 | 1.04.03.113 FS+0.5d | 0d |  | CAPATAZ [1 h]; PEON [1 h]; Tractor S/Orugas (D6T) - 180 HP [1 h]; Excavadora Sobre Oruga 260 HP [1 h] |
|  | 2 | **EXCAVACIÓN DE UÑA CON EQUIPO** |  | 2024-01-05 | 2024-09-07 |  |  |  |  |
| 1.04.03.10 |  | EXCAVACIÓN DE UÑA CON EQUIPO A2-I-05 | 4d | 2024-01-05 | 2024-01-09 | 1.04.03.01 FS-3d | 57.7d | 0d | CAPATAZ [2.93 h]; Excavadora Sobre Oruga 260 HP [29 h]; PEON [29 h] |
| 1.04.03.11 |  | EXCAVACIÓN DE UÑA CON EQUIPO A2-I-04 | 17d | 2024-01-29 | 2024-02-16 | 1.04.03.02 FS-17d | 108.8d | 0d | CAPATAZ [13.24 h]; Excavadora Sobre Oruga 260 HP [132.42 h]; PEON [132 h] |
| 1.04.03.12 |  | EXCAVACIÓN DE UÑA CON EQUIPO A2-I-07 | 13.5d | 2024-02-06 | 2024-02-21 | 1.04.03.03 FS-13d | 91.8d | 0d | CAPATAZ [23.74 h]; Excavadora Sobre Oruga 260 HP [237.44 h]; PEON [237.44 h] |
| 1.04.03.13 |  | EXCAVACIÓN DE UÑA CON EQUIPO A2-I-06 | 8d | 2024-02-26 | 2024-03-05 | 1.04.03.04 FS-8d | 101.8d | 0d | CAPATAZ [6.06 h]; Excavadora Sobre Oruga 260 HP [60.58 h]; PEON [60.58 h] |
| 1.04.03.14 |  | EXCAVACIÓN DE UÑA CON EQUIPO A2-D-03 | 16.5d | 2024-03-23 | 2024-04-13 | 1.04.03.05 FS-16.5d | 23.91d | 0d | CAPATAZ [13.07 h]; Excavadora Sobre Oruga 260 HP [130.68 h]; PEON [130.68 h] |
| 1.04.03.15 |  | EXCAVACIÓN DE UÑA CON EQUIPO A2-D-06 | 26.5d | 2024-04-08 | 2024-05-09 | 1.04.03.06 FS-24.5d | 53.8d | 0d | CAPATAZ [23.72 h]; Excavadora Sobre Oruga 260 HP [237.25 h]; PEON [237.25 h] |
| 1.04.03.16 |  | EXCAVACIÓN DE UÑA CON EQUIPO A2-D-05 | 7.5d | 2024-05-13 | 2024-05-21 | 1.04.03.07 FS-7.5d | 54.8d | 0d | CAPATAZ [6.06 h]; Excavadora Sobre Oruga 260 HP [60.55 h]; PEON [60.55 h] |
| 1.04.03.17 |  | EXCAVACIÓN DE UÑA CON EQUIPO A2-D-04 | 3.5d | 2024-05-23 | 2024-05-27 | 1.04.03.07 FS+1.5d | 0d |  | CAPATAZ [3.05 h]; Excavadora Sobre Oruga 260 HP [30.51 h]; PEON [30.51 h] |
| 1.04.03.17.1 |  | EXCAVACIÓN DE UÑA CON EQUIPO TOMAS | 0.5d | 2024-08-28 | 2024-08-28 | 1.04.03.103 FS+0.5d | 37.8d | 0d | CAPATAZ [1 h]; Excavadora Sobre Oruga 260 HP [1 h]; PEON [1 h] |
| 1.04.03.17.11 |  | EXCAVACIÓN DE UÑA CON EQUIPO RETORNOS | 0.5d | 2024-08-29 | 2024-08-29 | 1.04.03.113 FS+0.5d | 35.8d | 0d | CAPATAZ [1 h]; Excavadora Sobre Oruga 260 HP [1 h]; PEON [1 h] |
| 1.04.03.17.21 |  | EXCAVACIÓN DE UÑA CON EQUIPO LIBERACIÓN PREDIAL | 3.5d | 2024-09-04 | 2024-09-07 | 1.04.03.93 FS+0.5d | 0d |  | CAPATAZ [1 h]; Excavadora Sobre Oruga 260 HP [1 h]; PEON [1 h] |

| ID | WBS | Activity | Duration | Start | Finish | Predecessors | Total float | Free float | Resources |
| --- | --- | --- | --- | --- | --- | --- | --- | --- | --- |
|  | 3 | **PERFILADO Y COMPACTACIÓN EN ZONA DE CORTE** |  | 2024-01-10 | 2024-09-09 |  |  |  |  |
| 1.04.03.18 |  | PERFILADO Y COMPACTACIÓN EN ZONA DE CORTE A2-I-05 | 0.5d | 2024-01-10 | 2024-01-10 | 1.04.03.10 | 57.7d | 0d | CAPATAZ; Excavadora Sobre Oruga 260 HP [0.2 h]; PEON [0.53 h]; Rodillo Vib. Liso Autopropulsado 135 HP 12 TM [0.53 h]; Motoniveladora 185 HP [0.26 h]; Camión Cisterna 4x2 400 HP Agua (5000 gal) [0.26 h] |
| 1.04.03.19 |  | PERFILADO Y COMPACTACIÓN EN ZONA DE CORTE A2-I-04 | 2.5d | 2024-02-17 | 2024-02-20 | 1.04.03.11 | 108.8d | 0d | CAPATAZ [2.8 h]; Excavadora Sobre Oruga 260 HP [12.59 h]; PEON [25.18 h]; Rodillo Vib. Liso Autopropulsado 135 HP 12 TM [25.18 h]; Motoniveladora 185 HP [12.59 h]; Camión Cisterna 4x2 400 HP Agua (5000 gal) [12.59 h] |
| 1.04.03.20 |  | PERFILADO Y COMPACTACIÓN EN ZONA DE CORTE A2-I-07 | 3d | 2024-02-22 | 2024-02-24 | 1.04.03.12 | 91.8d | 0d | CAPATAZ [2.7 h]; Excavadora Sobre Oruga 260 HP [12.14 h]; PEON [24.28 h]; Rodillo Vib. Liso Autopropulsado 135 HP 12 TM [24.28 h]; Motoniveladora 185 HP [12.14 h]; Camión Cisterna 4x2 400 HP Agua (5000 gal) [12.14 h] |
| 1.04.03.21 |  | PERFILADO Y COMPACTACIÓN EN ZONA DE CORTE A2-I-06 | 1d | 2024-03-06 | 2024-03-06 | 1.04.03.13 | 101.8d | 0d | CAPATAZ [0.48 h]; Excavadora Sobre Oruga 260 HP [2.14 h]; PEON [4.28 h]; Rodillo Vib. Liso Autopropulsado 135 HP 12 TM [4.28 h]; Motoniveladora 185 HP [2.14 h]; Camión Cisterna 4x2 400 HP Agua (5000 gal) [2.14 h] |
| 1.04.03.22 |  | PERFILADO Y COMPACTACIÓN EN ZONA DE CORTE A2-D-03 | 4.5d | 2024-04-15 | 2024-04-19 | 1.04.03.14 FS+0.5d | 23.91d | 0d | CAPATAZ [4.32 h]; Excavadora Sobre Oruga 260 HP [19.44 h]; PEON [38.88 h]; Rodillo Vib. Liso Autopropulsado 135 HP 12 TM [38.88 h]; Motoniveladora 185 HP [19.44 h]; Camión Cisterna 4x2 400 HP Agua (5000 gal) [19.44 h] |
| 1.04.03.23 |  | PERFILADO Y COMPACTACIÓN EN ZONA DE CORTE A2-D-06 | 1.5d | 2024-05-10 | 2024-05-11 | 1.04.03.15 FS+0.5d | 53.8d | 0d | CAPATAZ [1.31 h]; Excavadora Sobre Oruga 260 HP [5.89 h]; PEON [11.77 h]; Rodillo Vib. Liso Autopropulsado 135 HP 12 TM [12 h]; Motoniveladora 185 HP [5.89 h]; Camión Cisterna 4x2 400 HP Agua (5000 gal) [5.89 h] |
| 1.04.03.24 |  | PERFILADO Y COMPACTACIÓN EN ZONA DE CORTE A2-D-05 | 0.5d | 2024-05-22 | 2024-05-22 | 1.04.03.16 FS+0.5d | 54.8d | 0d | CAPATAZ [0.84 h]; Excavadora Sobre Oruga 260 HP [3.77 h]; PEON [7.54 h]; Rodillo Vib. Liso Autopropulsado 135 HP 12 TM [7.54 h]; Motoniveladora 185 HP [3.77 h]; Camión Cisterna 4x2 400 HP Agua (5000 gal) [3.77 h] |
| 1.04.03.25 |  | PERFILADO Y COMPACTACIÓN EN ZONA DE CORTE A2-D-04 | 0.5d | 2024-05-28 | 2024-05-28 | 1.04.03.17 FS+0.5d | 0d |  | CAPATAZ [0.58 h]; Excavadora Sobre Oruga 260 HP [2.62 h]; PEON [5.25 h]; Rodillo Vib. Liso Autopropulsado 135 HP 12 TM [5.25 h]; Motoniveladora 185 HP [2.62 h]; Camión Cisterna 4x2 400 HP Agua (5000 gal) [2.62 h] |
| 1.04.03.25.1 |  | PERFILADO Y COMPACTACIÓN EN ZONA DE CORTE TOMAS | 0.5d | 2024-08-29 | 2024-08-29 | 1.04.03.17.1 FS+0.5d | 37.8d | 0d | CAPATAZ [0.58 h]; Excavadora Sobre Oruga 260 HP [1 h]; PEON [1 h]; Rodillo Vib. Liso Autopropulsado 135 HP 12 TM [1 h]; Motoniveladora 185 HP [1 h]; Camión Cisterna 4x2 400 HP Agua (5000 gal) [1 h] |
| 1.04.03.25.11 |  | PERFILADO Y COMPACTACIÓN EN ZONA DE CORTE RETORNOS | 0.5d | 2024-08-31 | 2024-08-31 | 1.04.03.17.11 FS+0.5d | 35.8d | 0d | CAPATAZ [0.58 h]; Excavadora Sobre Oruga 260 HP [1 h]; PEON [1 h]; Rodillo Vib. Liso Autopropulsado 135 HP 12 TM [1 h]; Motoniveladora 185 HP [1 h]; Camión Cisterna 4x2 400 HP Agua (5000 gal) [1 h] |
| 1.04.03.25.21 |  | PERFILADO Y COMPACTACIÓN EN ZONA DE CORTE LIBERACIÓN PREDIAL | 0.5d | 2024-09-09 | 2024-09-09 | 1.04.03.17.21 FS+0.5d | 0d |  | CAPATAZ [0.58 h]; Excavadora Sobre Oruga 260 HP [1 h]; PEON [1 h]; Rodillo Vib. Liso Autopropulsado 135 HP 12 TM [1 h]; Motoniveladora 185 HP [1 h]; Camión Cisterna 4x2 400 HP Agua (5000 gal) [1 h] |
|  | 4 | **PERFILADO EN ZONA DE CORTE EN FUNDACION Y TALUD** |  | 2024-01-20 | 2024-09-24 |  |  |  |  |
| 1.04.03.26 |  | PERFILADO EN ZONA DE CORTE EN FUNDACION Y TALUD A2-I-05 | 3d | 2024-01-20 | 2024-01-23 | 1.04.03.42 | 59.79d | 0d | Camión Cisterna 4x2 400 HP Agua (5000 gal) [0.26 h]; CAPATAZ [0.06 h]; Motoniveladora 185 HP [0.26 h]; PEON [0.53 h]; Rodillo Vib. Liso Autopropulsado 135 HP 12 TM [0.53 h]; Excavadora Sobre Oruga 260 HP [0.26 h] |
| 1.04.03.27 |  | PERFILADO EN ZONA DE CORTE EN FUNDACION Y TALUD A2-I-04 | 6d | 2024-03-05 | 2024-03-11 | 1.04.03.43 | 108.8d | 0d | Camión Cisterna 4x2 400 HP Agua (5000 gal) [45.89 h]; CAPATAZ [10.2 h]; Motoniveladora 185 HP [45.89 h]; PEON [91.79 h]; Rodillo Vib. Liso Autopropulsado 135 HP 12 TM [91.79 h]; Excavadora Sobre Oruga 260 HP [45.89 h] |
| 1.04.03.29 |  | PERFILADO EN ZONA DE CORTE EN FUNDACION Y TALUD A2-I-06 | 5d | 2024-03-23 | 2024-03-30 | 1.04.03.45 | 101.8d | 0d | Camión Cisterna 4x2 400 HP Agua (5000 gal) [17.72 h]; CAPATAZ [3.94 h]; Motoniveladora 185 HP [17.72 h]; PEON [35.44 h]; Rodillo Vib. Liso Autopropulsado 135 HP 12 TM [35.44 h]; Excavadora Sobre Oruga 260 HP [17.72 h] |
| 1.04.03.28 |  | PERFILADO EN ZONA DE CORTE EN FUNDACION Y TALUD A2-I-07 | 7.5d | 2024-04-01 | 2024-04-09 | 1.04.03.44 FS+0.5d | 91.8d | 0d | Camión Cisterna 4x2 400 HP Agua (5000 gal) [63.24 h]; CAPATAZ [14.05 h]; Motoniveladora 185 HP [63.24 h]; PEON [126.48 h]; Rodillo Vib. Liso Autopropulsado 135 HP 12 TM [126.48 h]; Excavadora Sobre Oruga 260 HP [63.24 h] |
| 1.04.03.30 |  | PERFILADO EN ZONA DE CORTE EN FUNDACION Y TALUD A2-D-03 | 14.5d | 2024-04-23 | 2024-05-10 | 1.04.03.46 FS+0.5d | 23.91d | 0d | Camión Cisterna 4x2 400 HP Agua (5000 gal) [55.46 h]; CAPATAZ [12.32 h]; Motoniveladora 185 HP [55.46 h]; PEON [110.91 h]; Rodillo Vib. Liso Autopropulsado 135 HP 12 TM [111 h]; Excavadora Sobre Oruga 260 HP [55.46 h] |
| 1.04.03.32 |  | PERFILADO EN ZONA DE CORTE EN FUNDACION Y TALUD A2-D-05 | 4.5d | 2024-06-03 | 2024-06-07 | 1.04.03.48 FS+0.5d | 54.8d | 0d | Camión Cisterna 4x2 400 HP Agua (5000 gal) [17.84 h]; CAPATAZ [3.97 h]; Motoniveladora 185 HP [17.84 h]; PEON [35.69 h]; Rodillo Vib. Liso Autopropulsado 135 HP 12 TM [35.69 h]; Excavadora Sobre Oruga 260 HP [17.84 h] |
| 1.04.03.31 |  | PERFILADO EN ZONA DE CORTE EN FUNDACION Y TALUD A2-D-06 | 7.5d | 2024-06-04 | 2024-06-12 | 1.04.03.47 FS+0.5d | 53.8d | 0d | Camión Cisterna 4x2 400 HP Agua (5000 gal) [65.5 h]; CAPATAZ [14.56 h]; Motoniveladora 185 HP [65.5 h]; PEON [131 h]; Rodillo Vib. Liso Autopropulsado 135 HP 12 TM [131 h]; Excavadora Sobre Oruga 260 HP [65.5 h] |
| 1.04.03.33 |  | PERFILADO EN ZONA DE CORTE EN FUNDACION Y TALUD A2-D-04 | 2.5d | 2024-06-04 | 2024-06-06 | 1.04.03.49 FS+0.5d | 0d |  | Camión Cisterna 4x2 400 HP Agua (5000 gal) [9.98 h]; CAPATAZ [2.22 h]; Motoniveladora 185 HP [9.98 h]; PEON [19.95 h]; Rodillo Vib. Liso Autopropulsado 135 HP 12 TM [19.95 h]; Excavadora Sobre Oruga 260 HP [9.98 h] |
| 1.04.03.33.01 |  | PERFILADO EN ZONA DE CORTE EN FUNDACION Y TALUD TOMAS | 0.5d | 2024-09-04 | 2024-09-04 | 1.04.03.49.01 FS+0.5d | 37.8d | 0d | Camión Cisterna 4x2 400 HP Agua (5000 gal) [1 h]; CAPATAZ [1 h]; Motoniveladora 185 HP [1 h]; PEON [1 h]; Rodillo Vib. Liso Autopropulsado 135 HP 12 TM [1 h]; Excavadora Sobre Oruga 260 HP [1 h] |
| 1.04.03.33.1 |  | PERFILADO EN ZONA DE CORTE EN FUNDACION Y TALUD RETORNOS | 0.5d | 2024-09-05 | 2024-09-05 | 1.04.03.49.1 FS+0.5d | 35.8d | 0d | Camión Cisterna 4x2 400 HP Agua (5000 gal) [1 h]; CAPATAZ [1 h]; Motoniveladora 185 HP [1 h]; PEON [1 h]; Rodillo Vib. Liso Autopropulsado 135 HP 12 TM [1 h]; Excavadora Sobre Oruga 260 HP [1 h] |
| 1.04.03.33.11 |  | PERFILADO EN ZONA DE CORTE EN FUNDACION Y TALUD PERFILADO EN ZONA DE CORTE EN FUNDACION Y TALUD LIBERACIÓN PREDIAL | 2.5d | 2024-09-21 | 2024-09-24 | 1.04.03.49.11 FS+0.5d | 0d |  | Camión Cisterna 4x2 400 HP Agua (5000 gal) [1 h]; CAPATAZ [1 h]; Motoniveladora 185 HP [1 h]; PEON [1 h]; Rodillo Vib. Liso Autopropulsado 135 HP 12 TM [1 h]; Excavadora Sobre Oruga 260 HP [1 h] |

| ID | WBS | Activity | Duration | Start | Finish | Predecessors | Total float | Free float | Resources |
| --- | --- | --- | --- | --- | --- | --- | --- | --- | --- |
|  | 5 | **PREPARACIÓN DE FUNDACIÓN DE CUERPO DE DIQUE** |  | 2024-01-11 | 2024-09-11 |  |  |  |  |
| 1.04.03.34 |  | PREPARACIÓN DE FUNDACIÓN DE CUERPO DE DIQUE A2-I-05 | 1.5d | 2024-01-11 | 2024-01-12 | 1.04.03.18 FS+1d | 57.7d | 0d | Camión Cisterna 4x2 400 HP Agua (5000 gal) [4.91 h]; CAPATAZ [1.09 h]; Motoniveladora 185 HP [4.91 h]; PEON [9.81 h]; Rodillo Vib. Liso Autopropulsado 135 HP 12 TM [9.81 h]; Excavadora Sobre Oruga 260 HP [2.45 h] |
| 1.04.03.35 |  | PREPARACIÓN DE FUNDACIÓN DE CUERPO DE DIQUE A2-I-04 | 2.5d | 2024-02-21 | 2024-02-23 | 1.04.03.19 FS+1d | 108.8d | 0d | Camión Cisterna 4x2 400 HP Agua (5000 gal) [9.45 h]; CAPATAZ [2.1 h]; Motoniveladora 185 HP [9.45 h]; PEON [18.91 h]; Rodillo Vib. Liso Autopropulsado 135 HP 12 TM [18.91 h]; Excavadora Sobre Oruga 260 HP [4.73 h] |
| 1.04.03.36 |  | PREPARACIÓN DE FUNDACIÓN DE CUERPO DE DIQUE A2-I-07 | 4d | 2024-02-26 | 2024-02-29 | 1.04.03.20 | 91.8d | 0d | Camión Cisterna 4x2 400 HP Agua (5000 gal) [35.96 h]; CAPATAZ [7.99 h]; Motoniveladora 185 HP [35.96 h]; PEON [71.92 h]; Rodillo Vib. Liso Autopropulsado 135 HP 12 TM [71.92 h]; Excavadora Sobre Oruga 260 HP [17.98 h] |
| 1.04.03.37 |  | PREPARACIÓN DE FUNDACIÓN DE CUERPO DE DIQUE A2-I-06 | 2d | 2024-03-07 | 2024-03-08 | 1.04.03.21 | 101.8d | 0d | Camión Cisterna 4x2 400 HP Agua (5000 gal) [8.59 h]; CAPATAZ [1.91 h]; Motoniveladora 185 HP [8.59 h]; PEON [17.18 h]; Rodillo Vib. Liso Autopropulsado 135 HP 12 TM [17.18 h]; Excavadora Sobre Oruga 260 HP [4.29 h] |
| 1.04.03.38 |  | PREPARACIÓN DE FUNDACIÓN DE CUERPO DE DIQUE A2-D-03 | 0.5d | 2024-04-20 | 2024-04-20 | 1.04.03.22 FS+0.5d | 23.91d | 0d | Camión Cisterna 4x2 400 HP Agua (5000 gal) [0.68 h]; CAPATAZ [0.15 h]; Motoniveladora 185 HP [0.68 h]; PEON [1.35 h]; Rodillo Vib. Liso Autopropulsado 135 HP 12 TM [1.35 h]; Excavadora Sobre Oruga 260 HP [0.34 h] |
| 1.04.03.39 |  | PREPARACIÓN DE FUNDACIÓN DE CUERPO DE DIQUE A2-D-06 | 4.5d | 2024-05-13 | 2024-05-17 | 1.04.03.23 FS+0.5d | 53.8d | 0d | Camión Cisterna 4x2 400 HP Agua (5000 gal) [44.37 h]; CAPATAZ [9.86 h]; Motoniveladora 185 HP [44.37 h]; PEON [88.74 h]; Rodillo Vib. Liso Autopropulsado 135 HP 12 TM [88.74 h]; Excavadora Sobre Oruga 260 HP [22.19 h] |
| 1.04.03.40 |  | PREPARACIÓN DE FUNDACIÓN DE CUERPO DE DIQUE A2-D-05 | 1.5d | 2024-05-23 | 2024-05-24 | 1.04.03.24 FS+0.5d | 54.8d | 0d | Camión Cisterna 4x2 400 HP Agua (5000 gal) [5.5 h]; CAPATAZ [1.22 h]; Motoniveladora 185 HP [5.5 h]; PEON [10.99 h]; Rodillo Vib. Liso Autopropulsado 135 HP 12 TM [10.99 h]; Excavadora Sobre Oruga 260 HP [2.75 h] |
| 1.04.03.41 |  | PREPARACIÓN DE FUNDACIÓN DE CUERPO DE DIQUE A2-D-04 | 0.5d | 2024-05-29 | 2024-05-29 | 1.04.03.25 FS+0.5d | 0d |  | Camión Cisterna 4x2 400 HP Agua (5000 gal) [2.25 h]; CAPATAZ [0.5 h]; Motoniveladora 185 HP [4.91 h]; PEON [4.49 h]; Rodillo Vib. Liso Autopropulsado 135 HP 12 TM [2.25 h]; Excavadora Sobre Oruga 260 HP [1.12 h] |
| 1.04.03.41.01 |  | PREPARACIÓN DE FUNDACIÓN DE CUERPO DE DIQUE - TOMAS | 0.5d | 2024-08-31 | 2024-08-31 | 1.04.03.25.1 FS+0.5d | 37.8d | 0d | Camión Cisterna 4x2 400 HP Agua (5000 gal) [1 h]; CAPATAZ [0.5 h]; Motoniveladora 185 HP [1 h]; PEON [1 h]; Rodillo Vib. Liso Autopropulsado 135 HP 12 TM [1 h]; Excavadora Sobre Oruga 260 HP [1.12 h] |
| 1.04.03.41.1 |  | PREPARACIÓN DE FUNDACIÓN DE CUERPO DE DIQUE - RETORNOS | 0.5d | 2024-09-02 | 2024-09-02 | 1.04.03.25.11 FS+0.5d | 35.8d | 0d | Camión Cisterna 4x2 400 HP Agua (5000 gal) [1 h]; CAPATAZ [0.5 h]; Motoniveladora 185 HP [1 h]; PEON [1 h]; Rodillo Vib. Liso Autopropulsado 135 HP 12 TM [1 h]; Excavadora Sobre Oruga 260 HP [1.12 h] |
| 1.04.03.41.11 |  | PREPARACIÓN DE FUNDACIÓN DE CUERPO DE DIQUE - LIBERACIÓN PREDIAL | 1.5d | 2024-09-10 | 2024-09-11 | 1.04.03.25.21 FS+0.5d | 0d |  | Camión Cisterna 4x2 400 HP Agua (5000 gal) [1 h]; CAPATAZ [0.5 h]; Motoniveladora 185 HP [1 h]; PEON [1 h]; Rodillo Vib. Liso Autopropulsado 135 HP 12 TM [1 h]; Excavadora Sobre Oruga 260 HP [1.12 h] |
|  | 6 | **CONFORMACIÓN DE CUERPO DE DIQUE CON MATERIAL PROPIO** |  | 2024-01-13 | 2024-09-20 |  |  |  |  |
| 1.04.03.42 |  | CONFORMACIÓN DE CUERPO DE DIQUE CON MATERIAL PROPIO A2-I-05 | 6d | 2024-01-13 | 2024-01-19 | 1.04.03.34 | 57.7d | 0d | Camión Cisterna 4x2 400 HP Agua (5000 gal) [45.75 h]; CAPATAZ [45.75 h]; Motoniveladora 185 HP [45.75 h]; OPERARIO [45.75 h]; PEON [182.85 h]; Rodillo Vib. Liso Autopropulsado 135 HP 12 TM [45.75 h]; OFICIAL [45.75 h]; Excavadora Sobre Oruga 260 HP [45.75 h]; CARGADOR SOBRE LLANTAS DE 200-250 HP [22.79 h] |
| 1.04.03.43 |  | CONFORMACIÓN DE CUERPO DE DIQUE CON MATERIAL PROPIO A2-I-04 | 8d | 2024-02-24 | 2024-03-04 | 1.04.03.35 | 108.8d | 0d | Camión Cisterna 4x2 400 HP Agua (5000 gal) [63.01 h]; CAPATAZ [63.01 h]; Motoniveladora 185 HP [63.01 h]; OPERARIO [63.01 h]; PEON [251.79 h]; Rodillo Vib. Liso Autopropulsado 135 HP 12 TM [63.01 h]; OFICIAL [63.01 h]; Excavadora Sobre Oruga 260 HP [63.01 h]; CARGADOR SOBRE LLANTAS DE 200-250 HP [63.01 h] |
| 1.04.03.44 |  | CONFORMACIÓN DE CUERPO DE DIQUE CON MATERIAL PROPIO A2-I-07 | 23.5d | 2024-03-01 | 2024-03-30 | 1.04.03.36 | 91.8d | 0d | Camión Cisterna 4x2 400 HP Agua (5000 gal) [413.45 h]; CAPATAZ [413.45 h]; Motoniveladora 185 HP [413.45 h]; OPERARIO [413.45 h]; PEON [1652.24 h]; Rodillo Vib. Liso Autopropulsado 135 HP 12 TM [413.45 h]; OFICIAL [413.45 h]; Excavadora Sobre Oruga 260 HP [413.45 h]; CARGADOR SOBRE LLANTAS DE 200-250 HP [205.95 h] |
| 1.04.03.45 |  | CONFORMACIÓN DE CUERPO DE DIQUE CON MATERIAL PROPIO A2-I-06 | 12d | 2024-03-09 | 2024-03-22 | 1.04.03.37 | 101.8d | 0d | Camión Cisterna 4x2 400 HP Agua (5000 gal) [90.61 h]; CAPATAZ [90.61 h]; Motoniveladora 185 HP [90.61 h]; OPERARIO [90.61 h]; PEON [362.11 h]; Rodillo Vib. Liso Autopropulsado 135 HP 12 TM [90.61 h]; OFICIAL [90.61 h]; Excavadora Sobre Oruga 260 HP [90.61 h]; CARGADOR SOBRE LLANTAS DE 200-250 HP [45.14 h] |
| 1.04.03.46 |  | CONFORMACIÓN DE CUERPO DE DIQUE CON MATERIAL PROPIO A2-D-03 | 0.5d | 2024-04-22 | 2024-04-22 | 1.04.03.38 FS+0.5d | 23.91d | 0d | Camión Cisterna 4x2 400 HP Agua (5000 gal); CAPATAZ; Motoniveladora 185 HP; OPERARIO; PEON; Rodillo Vib. Liso Autopropulsado 135 HP 12 TM; OFICIAL; Excavadora Sobre Oruga 260 HP; CARGADOR SOBRE LLANTAS DE 200-250 HP |
| 1.04.03.47 |  | CONFORMACIÓN DE CUERPO DE DIQUE CON MATERIAL PROPIO A2-D-06 | 13.5d | 2024-05-18 | 2024-06-03 | 1.04.03.39 FS+0.5d | 53.8d | 0d | Camión Cisterna 4x2 400 HP Agua (5000 gal) [498.02 h]; CAPATAZ [498.02 h]; Motoniveladora 185 HP [498.02 h]; OPERARIO [498.02 h]; PEON [1990.22 h]; Rodillo Vib. Liso Autopropulsado 135 HP 12 TM [498.02 h]; OFICIAL [498.02 h]; Excavadora Sobre Oruga 260 HP [498.02 h]; CARGADOR SOBRE LLANTAS DE 200-250 HP [248.08 h] |
| 1.04.03.48 |  | CONFORMACIÓN DE CUERPO DE DIQUE CON MATERIAL PROPIO A2-D-05 | 6.5d | 2024-05-25 | 2024-06-01 | 1.04.03.40 FS+0.5d | 54.8d | 0d | Camión Cisterna 4x2 400 HP Agua (5000 gal) [52.2 h]; CAPATAZ [52.2 h]; Motoniveladora 185 HP [52.2 h]; OPERARIO [52.2 h]; PEON [208.61 h]; Rodillo Vib. Liso Autopropulsado 135 HP 12 TM [52.2 h]; OFICIAL [52.2 h]; Excavadora Sobre Oruga 260 HP [52.2 h]; CARGADOR SOBRE LLANTAS DE 200-250 HP [26 h] |
| 1.04.03.50 |  | CONFORMACIÓN DE CUERPO DE RAMPA CON MATERIAL PROPIO RAMPA | 10.5d | 2024-05-28 | 2024-06-08 | 1.04.03.94 FS+0.5d | 111.8d | 0d | Camión Cisterna 4x2 400 HP Agua (5000 gal) [86.08 h]; CAPATAZ [86.08 h]; Motoniveladora 185 HP [86.08 h]; OPERARIO [86.08 h]; PEON [344.01 h]; Rodillo Vib. Liso Autopropulsado 135 HP 12 TM [86.08 h]; OFICIAL [86.08 h]; Excavadora Sobre Oruga 260 HP [86.08 h]; CARGADOR SOBRE LLANTAS DE 200-250 HP [42.88 h] |
| 1.04.03.49 |  | CONFORMACIÓN DE CUERPO DE DIQUE CON MATERIAL PROPIO A2-D-04 | 3.5d | 2024-05-30 | 2024-06-03 | 1.04.03.41 FS+0.5d | 0d |  | Camión Cisterna 4x2 400 HP Agua (5000 gal) [31.58 h]; CAPATAZ [31.58 h]; Motoniveladora 185 HP [31.58 h]; OPERARIO [31.58 h]; PEON [126.19 h]; Rodillo Vib. Liso Autopropulsado 135 HP 12 TM [31.58 h]; OFICIAL [31.58 h]; Excavadora Sobre Oruga 260 HP [31.58 h]; CARGADOR SOBRE LLANTAS DE 200-250 HP [15.73 h] |
| 1.04.03.49.01 |  | CONFORMACIÓN DE CUERPO DE DIQUE CON MATERIAL PROPIO - TOMAS | 1.5d | 2024-09-02 | 2024-09-03 | 1.04.03.41.01 FS+0.5d | 37.8d | 0d | Camión Cisterna 4x2 400 HP Agua (5000 gal) [1 h]; CAPATAZ [1 h]; Motoniveladora 185 HP [1 h]; OPERARIO [1 h]; PEON [1 h]; Rodillo Vib. Liso Autopropulsado 135 HP 12 TM [31.58 h]; OFICIAL [1 h]; Excavadora Sobre Oruga 260 HP [1 h]; CARGADOR SOBRE LLANTAS DE 200-250 HP [1 h] |
| 1.04.03.49.1 |  | CONFORMACIÓN DE CUERPO DE DIQUE CON MATERIAL PROPIO - RETORNOS | 1.5d | 2024-09-03 | 2024-09-04 | 1.04.03.41.1 FS+0.5d | 35.8d | 0d | Camión Cisterna 4x2 400 HP Agua (5000 gal) [1 h]; CAPATAZ [1 h]; Motoniveladora 185 HP [1 h]; OPERARIO [1 h]; PEON [1 h]; Rodillo Vib. Liso Autopropulsado 135 HP 12 TM [1 h]; OFICIAL [1 h]; Excavadora Sobre Oruga 260 HP [1 h]; CARGADOR SOBRE LLANTAS DE 200-250 HP [1 h] |
| 1.04.03.49.11 |  | CONFORMACIÓN DE CUERPO DE DIQUE CON MATERIAL PROPIO - LIBERACIÓN PREDIAL | 7.5d | 2024-09-12 | 2024-09-20 | 1.04.03.41.11 FS+0.5d | 0d |  | Camión Cisterna 4x2 400 HP Agua (5000 gal) [1 h]; CAPATAZ [1 h]; Motoniveladora 185 HP [1 h]; OPERARIO [1 h]; PEON [1 h]; Rodillo Vib. Liso Autopropulsado 135 HP 12 TM [1 h]; OFICIAL [1 h]; Excavadora Sobre Oruga 260 HP [1 h]; CARGADOR SOBRE LLANTAS DE 200-250 HP [1 h] |

| ID | WBS | Activity | Duration | Start | Finish | Predecessors | Total float | Free float | Resources |
| --- | --- | --- | --- | --- | --- | --- | --- | --- | --- |
|  | 7 | **GEOTEXTIL NO TEJIDO 400 G/M2, INC. COLOCACIÓN** |  | 2024-01-24 | 2024-09-28 |  |  |  |  |
| 1.04.03.51 |  | GEOTEXTIL NO TEJIDO 400 G/M2, INC. COLOCACIÓN A2-I-05 | 4d | 2024-01-24 | 2024-01-27 | 1.04.03.26 | 59.79d | 0d | CAPATAZ [2.75 h]; OPERARIO [25.69 h]; PEON [102.76 h] |
| 1.04.03.52 |  | GEOTEXTIL NO TEJIDO 400 G/M2, INC. COLOCACIÓN A2-I-04 | 9d | 2024-03-12 | 2024-03-21 | 1.04.03.27 | 108.8d | 0d | CAPATAZ [13.08 h]; OPERARIO [130.77 h]; PEON [523.07 h] |
| 1.04.03.54 |  | GEOTEXTIL NO TEJIDO 400 G/M2, INC. COLOCACIÓN A2-I-06 | 6.5d | 2024-04-01 | 2024-04-08 | 1.04.03.29 | 101.8d | 0d | CAPATAZ [5 h]; OPERARIO [50.05 h]; PEON [200.2 h] |
| 1.04.03.53 |  | GEOTEXTIL NO TEJIDO 400 G/M2, INC. COLOCACIÓN A2-I-07 | 11.5d | 2024-04-10 | 2024-04-23 | 1.04.03.28 FS+0.5d | 91.8d | 0d | CAPATAZ [20.42 h]; OPERARIO [204.23 h]; PEON [816.93 h] |
| 1.04.03.55 |  | GEOTEXTIL NO TEJIDO 400 G/M2, INC. COLOCACIÓN A2-D-03 | 8.5d | 2024-05-11 | 2024-05-21 | 1.04.03.30 FS+0.5d | 23.91d | 0d | CAPATAZ [12.82 h]; OPERARIO [128.19 h]; PEON [512.75 h] |
| 1.04.03.56 |  | GEOTEXTIL NO TEJIDO 400 G/M2, INC. COLOCACIÓN A2-D-06 | 11.5d | 2024-06-13 | 2024-06-26 | 1.04.03.31 FS+0.5d | 53.8d | 0d | CAPATAZ [20.04 h]; OPERARIO [200.43 h]; PEON [801.72 h] |
| 1.04.03.57 |  | GEOTEXTIL NO TEJIDO 400 G/M2, INC. COLOCACIÓN A2-D-05 | 6.5d | 2024-06-24 | 2024-07-02 | 1.04.03.32 FS+13.5d | 54.8d | 0d | CAPATAZ [4.97 h]; OPERARIO [49.67 h]; PEON [198.7 h] |
| 1.04.03.58 |  | GEOTEXTIL NO TEJIDO 400 G/M2, INC. COLOCACIÓN A2-D-04 | 3.5d | 2024-07-01 | 2024-07-04 | 1.04.03.33 FS+19.5d | 0d |  | CAPATAZ [2.7 h]; OPERARIO [27.01 h]; PEON [108.03 h] |
| 1.04.03.58.01 |  | GEOTEXTIL NO TEJIDO 400 G/M2, INC. COLOCACIÓN - TOMAS | 0.5d | 2024-09-05 | 2024-09-05 | 1.04.03.33.01 FS+0.5d | 37.8d | 0d | CAPATAZ [1 h]; OPERARIO [1 h]; PEON [1 h] |
| 1.04.03.58.1 |  | GEOTEXTIL NO TEJIDO 400 G/M2, INC. COLOCACIÓN - RETORNOS | 0.5d | 2024-09-06 | 2024-09-06 | 1.04.03.33.1 FS+0.5d | 35.8d | 0d | CAPATAZ [1 h]; OPERARIO [1 h]; PEON [108.03 h] |
| 1.04.03.58.11 |  | GEOTEXTIL NO TEJIDO 400 G/M2, INC. COLOCACIÓN - LIBERACIÓN PREDIAL | 3.5d | 2024-09-25 | 2024-09-28 | 1.04.03.33.11 FS+0.5d | 0d |  | CAPATAZ [1 h]; OPERARIO [1 h]; PEON [1 h] |
|  | 8 | **COLOCACION Y ACOMODO DE ROCA EN UÑA DE DIQUE** |  | 2024-01-26 | 2024-10-09 |  |  |  |  |
| 1.04.03.59 |  | COLOCACION Y ACOMODO DE ROCA EN UÑA DE DIQUE A2-I-05 | 8d | 2024-01-26 | 2024-02-03 | 1.04.03.51 FS-2d | 59.79d | 0d | CAPATAZ [133.17 h]; OPERARIO [133.17 h]; PEON [666.03 h]; Excavadora Sobre Oruga 260 HP [199.85 h] |
| 1.04.03.60 |  | COLOCACION Y ACOMODO DE ROCA EN UÑA DE DIQUE A2-I-04 | 31.5d | 2024-03-18 | 2024-04-25 | 1.04.03.52 FS-4d | 108.8d | 0d | CAPATAZ [601.7 h]; OPERARIO [601.7 h]; PEON [3009.35 h]; Excavadora Sobre Oruga 260 HP [902.97 h] |
| 1.04.03.61 |  | COLOCACION Y ACOMODO DE ROCA EN UÑA DE DIQUE A2-I-07 | 26.5d | 2024-04-19 | 2024-05-21 | 1.04.03.53 FS-3.5d | 91.8d | 0d | CAPATAZ [1078.85 h]; OPERARIO [1078.85 h]; PEON [5395.75 h]; Excavadora Sobre Oruga 260 HP [1619.02 h] |
| 1.04.03.62 |  | COLOCACION Y ACOMODO DE ROCA EN UÑA DE DIQUE A2-I-06 | 14.5d | 2024-05-07 | 2024-05-23 | 1.04.03.54 FS+23.5d | 101.8d | 0d | CAPATAZ [275.27 h]; OPERARIO [275.27 h]; PEON [1376.75 h]; Excavadora Sobre Oruga 260 HP [413.1 h] |
| 1.04.03.63 |  | COLOCACION Y ACOMODO DE ROCA EN UÑA DE DIQUE A2-D-03 | 31.5d | 2024-05-16 | 2024-06-21 | 1.04.03.55 FS-4.5d | 23.91d | 0d | CAPATAZ [593.79 h]; OPERARIO [593.79 h]; PEON [2969.78 h]; Excavadora Sobre Oruga 260 HP [891.1 h] |
| 1.04.03.64 |  | COLOCACION Y ACOMODO DE ROCA EN UÑA DE DIQUE A2-D-06 | 25.5d | 2024-06-22 | 2024-07-23 | 1.04.03.56 FS-3.5d | 53.8d | 0d | CAPATAZ [1078 h]; OPERARIO [1078 h]; PEON [5391.49 h]; Excavadora Sobre Oruga 260 HP [1617.74 h] |
| 1.04.03.65 |  | COLOCACION Y ACOMODO DE ROCA EN UÑA DE DIQUE A2-D-05 | 14.5d | 2024-07-13 | 2024-07-31 | 1.04.03.57 FS+9.5d | 54.8d | 0d | CAPATAZ [275.12 h]; OPERARIO [275.12 h]; PEON [1376 h]; Excavadora Sobre Oruga 260 HP [412.88 h] |
| 1.04.03.66 |  | COLOCACION Y ACOMODO DE ROCA EN UÑA DE DIQUE A2-D-04 | 7.5d | 2024-07-30 | 2024-08-07 | 1.04.03.58 FS+20.5d | 0d |  | CAPATAZ [138.63 h]; OPERARIO [138.63 h]; PEON [693.33 h]; Excavadora Sobre Oruga 260 HP [208.04 h] |
| 1.04.03.66.01 |  | COLOCACION Y ACOMODO DE ROCA EN UÑA DE DIQUE - TOMAS | 1.5d | 2024-09-06 | 2024-09-07 | 1.04.03.58.01 FS+0.5d | 37.8d | 0d | CAPATAZ [1 h]; OPERARIO [1 h]; PEON [1 h]; Excavadora Sobre Oruga 260 HP [1 h] |
| 1.04.03.66.1 |  | COLOCACION Y ACOMODO DE ROCA EN UÑA DE DIQUE - RETORNOS | 1.5d | 2024-09-07 | 2024-09-09 | 1.04.03.58.1 FS+0.5d | 35.8d | 0d | CAPATAZ [1 h]; OPERARIO [1 h]; PEON [1 h]; Excavadora Sobre Oruga 260 HP [1 h] |
| 1.04.03.66.11 |  | COLOCACION Y ACOMODO DE ROCA EN UÑA DE DIQUE - LIBERACIÓN PREDIAL | 7.5d | 2024-09-30 | 2024-10-09 | 1.04.03.58.11 FS+0.5d | 0d |  | CAPATAZ [1 h]; OPERARIO [1 h]; PEON [1 h]; Excavadora Sobre Oruga 260 HP [1 h] |

| ID | WBS | Activity | Duration | Start | Finish | Predecessors | Total float | Free float | Resources |
| --- | --- | --- | --- | --- | --- | --- | --- | --- | --- |
|  | 9 | **COLOCACION Y ACOMODO DE ROCA EN TALUD DE DIQUE** |  | 2024-02-05 | 2024-10-16 |  |  |  |  |
| 1.04.03.67 |  | COLOCACION Y ACOMODO DE ROCA EN TALUD DE DIQUE A2-I-05 | 13d | 2024-02-05 | 2024-02-19 | 1.04.03.59 | 205.3d | 0d | CAPATAZ [232.82 h]; PEON [1164.12 h]; Excavadora Sobre Oruga 260 HP [349.23 h]; OPERARIO [232.82 h] |
| 1.04.03.68 |  | COLOCACION Y ACOMODO DE ROCA EN TALUD DE DIQUE A2-I-04 | 50.5d | 2024-04-05 | 2024-06-04 | 1.04.03.60 FS-17.5d | 108.8d | 0d | CAPATAZ [977.3 h]; PEON [4886.5 h]; Excavadora Sobre Oruga 260 HP [1465.95 h]; OPERARIO [977.3 h] |
| 1.04.03.69 |  | COLOCACION Y ACOMODO DE ROCA EN TALUD DE DIQUE A2-I-07 | 38.5d | 2024-05-03 | 2024-06-17 | 1.04.03.61 FS-15.5d | 91.8d | 0d | CAPATAZ [1579.81 h]; PEON [7899.05 h]; Excavadora Sobre Oruga 260 HP [2369.71 h]; OPERARIO [1579.81 h] |
| 1.04.03.70 |  | COLOCACION Y ACOMODO DE ROCA EN TALUD DE DIQUE A2-I-06 | 22.5d | 2024-05-24 | 2024-06-19 | 1.04.03.62 FS+0.5d | 101.8d | 0d | CAPATAZ [437.48 h]; PEON [2187.38 h]; Excavadora Sobre Oruga 260 HP [656.21 h]; OPERARIO [437.48 h] |
| 1.04.03.71 |  | COLOCACION Y ACOMODO DE ROCA EN TALUD DE DIQUE A2-D-03 | 25.5d | 2024-06-22 | 2024-07-23 | 1.04.03.63 FS+0.5d | 23.91d | 0d | CAPATAZ [961.39 h]; PEON [4806.96 h]; Excavadora Sobre Oruga 260 HP [1442.09 h]; OPERARIO [961.39 h] |
| 1.04.03.72 |  | COLOCACION Y ACOMODO DE ROCA EN TALUD DE DIQUE A2-D-06 | 36.5d | 2024-07-01 | 2024-08-13 | 1.04.03.64 FS-19.5d | 53.8d | 0d | CAPATAZ [1576.8 h]; PEON [7884.01 h]; Excavadora Sobre Oruga 260 HP [2365.2 h]; OPERARIO [1576.8 h] |
| 1.04.03.73 |  | COLOCACION Y ACOMODO DE ROCA EN TALUD DE DIQUE A2-D-05 | 22.5d | 2024-07-19 | 2024-08-15 | 1.04.03.65 FS-9.5d | 54.8d | 0d | CAPATAZ [435.37 h]; PEON [2176.86 h]; Excavadora Sobre Oruga 260 HP [653.06 h]; OPERARIO [435.37 h] |
| 1.04.03.74 |  | COLOCACION Y ACOMODO DE ROCA EN TALUD DE DIQUE A2-D-04 | 12.5d | 2024-08-08 | 2024-08-22 | 1.04.03.66 FS+0.5d | 0d |  | CAPATAZ [244.26 h]; PEON [1221.31 h]; Excavadora Sobre Oruga 260 HP [366.39 h]; OPERARIO [244.26 h] |
| 1.04.03.74.01 |  | COLOCACION Y ACOMODO DE ROCA EN TALUD DE DIQUE - TOMAS | 1.5d | 2024-09-09 | 2024-09-10 | 1.04.03.66.01 FS+0.5d | 37.8d | 0d | CAPATAZ [1 h]; PEON [1 h]; Excavadora Sobre Oruga 260 HP [1 h]; OPERARIO [1 h] |
| 1.04.03.74.1 |  | COLOCACION Y ACOMODO DE ROCA EN TALUD DE DIQUE - RETORNOS | 2.5d | 2024-09-10 | 2024-09-12 | 1.04.03.66.1 FS+0.5d | 35.8d | 0d | CAPATAZ [1 h]; PEON [1 h]; Excavadora Sobre Oruga 260 HP [1 h]; OPERARIO [1 h] |
| 1.04.03.74.11 |  | COLOCACION Y ACOMODO DE ROCA EN TALUD DE DIQUE - LIBERACIÓN PREDIAL | 10.5d | 2024-10-03 | 2024-10-16 | 1.04.03.66.11 FS-4.5d | 0d |  | CAPATAZ [1 h]; PEON [1 h]; Excavadora Sobre Oruga 260 HP [1 h]; OPERARIO [1 h] |
|  | 10 | **CONFORMACIÓN DE MATERIAL GRANULAR EN CORONA DE DIQUE** |  | 2024-02-20 | 2024-10-19 |  |  |  |  |
| 1.04.03.75 |  | CONFORMACIÓN DE MATERIAL GRANULAR EN CORONA DE DIQUE A2-I-05 | 2d | 2024-02-20 | 2024-02-21 | 1.04.03.67 | 205.3d |  | Camión Cisterna 4x2 400 HP Agua (5000 gal) [15.79 h]; CAPATAZ [15.79 h]; Motoniveladora 185 HP [15.79 h]; OPERARIO [15.79 h]; PEON [63.09 h]; Rodillo Vib. Liso Autopropulsado 135 HP 12 TM [15.79 h]; OFICIAL [15.79 h]; Excavadora Sobre Oruga 260 HP [15.79 h]; CARGADOR SOBRE LLANTAS DE 200-250 HP [7.89 h] |
| 1.04.03.76 |  | CONFORMACIÓN DE MATERIAL GRANULAR EN CORONA DE DIQUE A2-I-04 | 10.5d | 2024-06-05 | 2024-06-17 | 1.04.03.68 FS+0.5d | 108.8d |  | Camión Cisterna 4x2 400 HP Agua (5000 gal) [86.47 h]; CAPATAZ [86.47 h]; Motoniveladora 185 HP [86.47 h]; OPERARIO [86.47 h]; PEON [345.57 h]; Rodillo Vib. Liso Autopropulsado 135 HP 12 TM [86.47 h]; OFICIAL [86.47 h]; Excavadora Sobre Oruga 260 HP [86.47 h]; CARGADOR SOBRE LLANTAS DE 200-250 HP [86.47 h] |
| 1.04.03.83 |  | CONFORMACIÓN DE CORONA DE RAMPA | 3.5d | 2024-06-10 | 2024-06-13 | 1.04.03.50 FS+0.5d | 111.8d |  | Camión Cisterna 4x2 400 HP Agua (5000 gal) [30.57 h]; CAPATAZ [30.57 h]; Motoniveladora 185 HP [30.57 h]; OPERARIO [30.57 h]; PEON [122.16 h]; Rodillo Vib. Liso Autopropulsado 135 HP 12 TM [30.57 h]; OFICIAL [30.57 h]; Excavadora Sobre Oruga 260 HP [30.57 h]; CARGADOR SOBRE LLANTAS DE 200-250 HP [15.28 h] |
| 1.04.03.77 |  | CONFORMACIÓN DE MATERIAL GRANULAR EN CORONA DE DIQUE A2-I-07 | 16.5d | 2024-06-18 | 2024-07-08 | 1.04.03.69 FS+0.5d | 91.8d | 0d | Camión Cisterna 4x2 400 HP Agua (5000 gal) [140.21 h]; CAPATAZ [140.21 h]; Motoniveladora 185 HP [140.21 h]; OPERARIO [140.21 h]; PEON [560.36 h]; Rodillo Vib. Liso Autopropulsado 135 HP 12 TM [140.21 h]; OFICIAL [140.21 h]; Excavadora Sobre Oruga 260 HP [140.21 h]; CARGADOR SOBRE LLANTAS DE 200-250 HP [70.11 h] |
| 1.04.03.78 |  | CONFORMACIÓN DE MATERIAL GRANULAR EN CORONA DE DIQUE A2-I-06 | 4.5d | 2024-06-20 | 2024-06-25 | 1.04.03.70 FS+0.5d | 101.8d |  | Camión Cisterna 4x2 400 HP Agua (5000 gal) [32.48 h]; CAPATAZ [32.48 h]; Motoniveladora 185 HP [32.48 h]; OPERARIO [32.48 h]; PEON [129.81 h]; Rodillo Vib. Liso Autopropulsado 135 HP 12 TM [32.48 h]; OFICIAL [32.48 h]; Excavadora Sobre Oruga 260 HP [32.48 h]; CARGADOR SOBRE LLANTAS DE 200-250 HP [16.24 h] |
| 1.04.03.79 |  | CONFORMACIÓN DE MATERIAL GRANULAR EN CORONA DE DIQUE A2-D-03 | 10.5d | 2024-07-24 | 2024-08-06 | 1.04.03.71 FS+0.5d | 23.91d | 0d | Camión Cisterna 4x2 400 HP Agua (5000 gal) [84.46 h]; CAPATAZ [84.46 h]; Motoniveladora 185 HP [84.46 h]; OPERARIO [84.46 h]; PEON [337.56 h]; Rodillo Vib. Liso Autopropulsado 135 HP 12 TM [84.46 h]; OFICIAL [84.46 h]; Excavadora Sobre Oruga 260 HP [84.46 h]; CARGADOR SOBRE LLANTAS DE 200-250 HP [42.23 h] |
| 1.04.03.80 |  | CONFORMACIÓN DE MATERIAL GRANULAR EN CORONA DE DIQUE A2-D-06 | 7.5d | 2024-08-14 | 2024-08-22 | 1.04.03.72 FS+0.5d | 53.8d |  | Camión Cisterna 4x2 400 HP Agua (5000 gal) [141.6 h]; CAPATAZ [141.6 h]; Motoniveladora 185 HP [141.6 h]; OPERARIO [141.6 h]; PEON [565.91 h]; Rodillo Vib. Liso Autopropulsado 135 HP 12 TM [141.6 h]; OFICIAL [141.6 h]; Excavadora Sobre Oruga 260 HP [141.6 h]; CARGADOR SOBRE LLANTAS DE 200-250 HP [70.8 h] |
| 1.04.03.81 |  | CONFORMACIÓN DE MATERIAL GRANULAR EN CORONA DE DIQUE A2-D-05 | 5d | 2024-08-15 | 2024-08-21 | 1.04.03.73 | 54.8d |  | Camión Cisterna 4x2 400 HP Agua (5000 gal) [32.39 h]; CAPATAZ [32.39 h]; Motoniveladora 185 HP [32.39 h]; OPERARIO [32.39 h]; PEON [129.44 h]; Rodillo Vib. Liso Autopropulsado 135 HP 12 TM [32.39 h]; OFICIAL [32.39 h]; Excavadora Sobre Oruga 260 HP [32.39 h]; CARGADOR SOBRE LLANTAS DE 200-250 HP [16.19 h] |
| 1.04.03.82 |  | CONFORMACIÓN DE MATERIAL GRANULAR EN CORONA DE DIQUE A2-D-04 | 2.5d | 2024-08-23 | 2024-08-26 | 1.04.03.74 FS+0.5d | 0d |  | Camión Cisterna 4x2 400 HP Agua (5000 gal) [16.55 h]; CAPATAZ [16.55 h]; Motoniveladora 185 HP [16.55 h]; OPERARIO [16.55 h]; PEON [66.12 h]; Rodillo Vib. Liso Autopropulsado 135 HP 12 TM [16.55 h]; OFICIAL [16.55 h]; Excavadora Sobre Oruga 260 HP [16.55 h]; CARGADOR SOBRE LLANTAS DE 200-250 HP [8.27 h] |
| 1.04.03.82.1 |  | CONFORMACIÓN DE MATERIAL GRANULAR EN CORONA DE DIQUE - TOMAS | 0.5d | 2024-09-11 | 2024-09-11 | 1.04.03.74.01 FS+0.5d | 37.8d | 0d | Camión Cisterna 4x2 400 HP Agua (5000 gal) [1 h]; CAPATAZ [1 h]; Motoniveladora 185 HP [1 h]; OPERARIO [1 h]; PEON [1 h]; Rodillo Vib. Liso Autopropulsado 135 HP 12 TM [1 h]; OFICIAL [1 h]; Excavadora Sobre Oruga 260 HP [1 h]; CARGADOR SOBRE LLANTAS DE 200-250 HP [1 h] |
| 1.04.03.82.11 |  | CONFORMACIÓN DE MATERIAL GRANULAR EN CORONA DE DIQUE - RETORNOS | 0.5d | 2024-09-13 | 2024-09-13 | 1.04.03.74.1 FS+0.5d | 35.8d | 0d | Camión Cisterna 4x2 400 HP Agua (5000 gal) [1 h]; CAPATAZ [1 h]; Motoniveladora 185 HP [1 h]; OPERARIO [1 h]; PEON [1 h]; Rodillo Vib. Liso Autopropulsado 135 HP 12 TM [1 h]; OFICIAL [1 h]; Excavadora Sobre Oruga 260 HP [1 h]; CARGADOR SOBRE LLANTAS DE 200-250 HP [1 h] |
| 1.04.03.82.21 |  | CONFORMACIÓN DE MATERIAL GRANULAR EN CORONA DE DIQUE - LIBERACIÓN PREDIAL | 2.5d | 2024-10-17 | 2024-10-19 | 1.04.03.74.11 FS+0.5d | 0d |  | Camión Cisterna 4x2 400 HP Agua (5000 gal) [1 h]; CAPATAZ [1 h]; Motoniveladora 185 HP [1 h]; OPERARIO [1 h]; PEON [1 h]; Rodillo Vib. Liso Autopropulsado 135 HP 12 TM [1 h]; OFICIAL [1 h]; Excavadora Sobre Oruga 260 HP [1 h]; CARGADOR SOBRE LLANTAS DE 200-250 HP [1 h] |

| ID | WBS | Activity | Duration | Start | Finish | Predecessors | Total float | Free float | Resources |
| --- | --- | --- | --- | --- | --- | --- | --- | --- | --- |
|  | 4 | **CAPTACIONES Y RETORNOS** |  | 2024-03-26 | 2024-06-28 |  |  |  |  |
|  | 1 | **SUB PROYECTO A2 - TRAMO II** |  | 2024-03-26 | 2024-06-28 |  |  |  |  |
|  | 1 | **MOVIMIENTO DE TIERRAS** |  | 2024-03-26 | 2024-06-03 |  |  |  |  |
| 1.04.04.01 |  | EXCAVACIÓN ESTRUCTURAL PARA OBRAS DE ARTE - CAPTACIONES | 8.5d | 2024-03-26 | 2024-04-06 | 1.04.01.1 | 98.88d | 0d | CAPATAZ [13.97 h]; CUADRADOR/VIGÍA [139.73 h]; PEON [279.46 h]; Retroexcavador 58 HP [139.73 h] |
| 1.04.04.03 |  | RELLENO ESTRUCTURAL PARA OBRAS DE ARTE, CON MATERIAL PROPIO - CAPTACIONES | 4.5d | 2024-04-05 | 2024-04-10 | 1.04.04.01 FS-1.42d | 165.72d |  | CAPATAZ [6.79 h]; CUADRADOR/VIGÍA [67.8 h]; PEON [135.57 h]; Rodillo Vib. Liso Autopropulsado 135 HP 12 TM [67.8 h]; Retroexcavador 58 HP [16.96 h] |
| 1.04.04.02 |  | EXCAVACIÓN ESTRUCTURAL PARA OBRAS DE ARTE - RETORNOS | 11.5d | 2024-04-08 | 2024-04-20 | 1.04.04.01 FS+0.5d | 98.88d | 0d | CAPATAZ [19.2 h]; CUADRADOR/VIGÍA [191.96 h]; PEON [383.93 h]; Retroexcavador 58 HP [191.96 h] |
| 1.04.04.04 |  | RELLENO ESTRUCTURAL PARA OBRAS DE ARTE CON MATERIAL PROPIO - RETORNOS | 37.5d | 2024-04-19 | 2024-06-03 | 1.04.04.02 FS-1.5d | 120.8d |  | CAPATAZ [60.36 h]; CUADRADOR/VIGÍA [602.96 h]; PEON [1205.7 h]; Retroexcavador 58 HP [150.8 h]; Rodillo Vib. Liso Autopropulsado 135 HP 12 TM [602.96 h] |
|  | 2 | **CAPTACIONES** |  | 2024-04-08 | 2024-06-28 |  |  |  |  |
|  | 1 | **OBRAS DE CONCRETO** |  | 2024-04-08 | 2024-05-11 |  |  |  |  |
| 1.04.04.05 |  | CONCRETO f'c=100 kg/cm2 | 0.5d | 2024-04-08 | 2024-04-08 | 1.04.04.01 FS+0.47d | 133.89d | 0d | CAPATAZ [0.35 h]; OPERARIO [6.98 h]; PEON [13.95 h]; OFICIAL [3.49 h] |
| 1.04.04.09 |  | ACERO DE REFUERZO fy=4200 kg/cm2 | 16.5d | 2024-04-09 | 2024-04-27 | 1.04.04.05 FS+0.47d | 133.89d | 0d | CAPATAZ [78.68 h]; OPERARIO [786.77 h]; PEON [786.77 h] |
| 1.04.04.08 |  | ENCOFRADO Y DESENCOFRADO RECTO | 12.5d | 2024-04-18 | 2024-05-04 | 1.04.04.09 FS-8.03d | 133.89d | 0d | CAPATAZ [293.7 h]; OPERARIO [587.5 h]; PEON [587.5 h] |
| 1.04.04.06 |  | CONCRETO f'c=280 kg/cm2 | 3.5d | 2024-05-06 | 2024-05-09 | 1.04.04.08 FS+1.1d | 133.89d | 0d | CAPATAZ [4.84 h]; OPERARIO [96.88 h]; PEON [193.72 h]; OFICIAL [48.44 h] |
| 1.04.04.07 |  | CONCRETO CICLÓPEO f'c=280 kg/cm2 + 30% P.G. | 1d | 2024-05-10 | 2024-05-11 | 1.04.04.06 FS+0.47d | 133.89d | 0d | CAPATAZ [0.47 h]; OPERARIO [2.35 h]; PEON [4.69 h] |
|  | 2 | **ESTRUCTURAS METÁLICAS** |  | 2024-05-11 | 2024-05-18 |  |  |  |  |
| 1.04.04.10 |  | COMPUERTA METALICA PLANA DESLIZANTE DE 1.0x1.0 m | 1.5d | 2024-05-11 | 2024-05-13 | 1.04.04.07 | 133.89d | 0d | OPERARIO [12 h]; PEON [36 h]; OFICIAL [12 h] |
| 1.04.04.12 |  | REJILLA METÁLICA DE 1.00x1.00m | 0.5d | 2024-05-14 | 2024-05-14 | 1.04.04.10 FS+0.47d | 133.89d | 0d | OPERARIO [4.8 h]; PEON [9.6 h] |
| 1.04.04.14 |  | BARANDA DE FIERRO GALVANIZADO 1 1/2" | 0.5d | 2024-05-15 | 2024-05-15 | 1.04.04.12 FS+0.47d | 133.89d | 0d | CAPATAZ [0.36 h]; OPERARIO [7.2 h]; PEON [3.6 h]; OFICIAL [7.2 h] |
| 1.04.04.15 |  | ESCALERA TIPO GATO | 0.5d | 2024-05-16 | 2024-05-16 | 1.04.04.14 FS+0.47d | 133.89d | 0d | CAPATAZ [0.6 h]; OPERARIO [6 h]; PEON [12 h] |
| 1.04.04.16 |  | TAPA DE CONCRETO | 0.5d | 2024-05-18 | 2024-05-18 | 1.04.04.15 FS+1.5d | 133.89d |  | CAPATAZ [0.48 h]; OPERARIO [4.8 h]; PEON [9.6 h] |
|  | 3 | **TUBERIAS** |  | 2024-04-22 | 2024-06-14 |  |  |  |  |
| 1.04.04.17 |  | EXCAVACIÓN ESTRUCTURAL PARA OBRAS DE ARTE (buzones) | 0.5d | 2024-04-22 | 2024-04-22 | 1.04.04.02 FS+0.47d | 98.88d | 0d | CAPATAZ [0.64 h]; CUADRADOR/VIGÍA [6.43 h]; PEON [12.86 h]; Retroexcavador 58 HP [6.43 h] |
| 1.04.04.18 |  | EXCAVACIÓN DE ZANJA | 14.5d | 2024-04-23 | 2024-05-10 | 1.04.04.17 SS+1d | 98.88d | 0d | CAPATAZ [11.55 h]; CUADRADOR/VIGÍA [115.52 h]; PEON [231.05 h]; Retroexcavador 58 HP [115.52 h] |
| 1.04.04.20 |  | CAMA DE ARENA | 1.5d | 2024-05-11 | 2024-05-13 | 1.04.04.18 FS+0.47d | 110.99d | 0d | CAPATAZ [5.24 h]; PEON [41.96 h] |
| 1.04.04.29 |  | SUMINISTRO E INSTALACIÓN DE TUBERÍA GRP DN600 mm SN2500 | 2.5d | 2024-05-14 | 2024-05-16 | 1.04.04.20 FS+0.47d | 110.99d | 0d | CAPATAZ [30.26 h]; OPERARIO [302.52 h]; PEON [1512.52 h]; OFICIAL [151.24 h] |
| 1.04.04.21 |  | RELLENO SELECCIONADO PARA ZANJA con material propio | 12.5d | 2024-05-17 | 2024-05-31 | 1.04.04.29 FS+0.47d | 110.99d | 0d | CAPATAZ [38.56 h]; CUADRADOR/VIGÍA [385.13 h]; PEON [1540.38 h]; Rodillo Vib. Liso Autopropulsado 135 HP 12 TM [385.13 h]; Retroexcavador 58 HP [96.32 h] |
| 1.04.04.23 |  | CONCRETO f'c=100 kg/cm2 (buzones) | 0.5d | 2024-06-01 | 2024-06-01 | 1.04.04.21 FS+1d | 110.99d | 0d | CAPATAZ [0.04 h]; OPERARIO [0.73 h]; PEON [1.46 h]; OFICIAL [0.37 h] |
| 1.04.04.27 |  | ACERO DE REFUERZO fy=4200 kg/cm2 | 1.5d | 2024-06-03 | 2024-06-04 | 1.04.04.23 FS+0.47d | 110.99d | 0d | CAPATAZ [0.89 h]; OPERARIO [8.94 h]; PEON [8.94 h] |
| 1.04.04.25 |  | ENCOFRADO Y DESENCOFRADO RECTO | 2.5d | 2024-06-05 | 2024-06-07 | 1.04.04.27 FS+0.47d | 110.99d | 0d | CAPATAZ [8.96 h]; OPERARIO [17.92 h]; PEON [18 h] |
| 1.04.04.26 |  | ENCOFRADO Y DESENCOFRADO CURVO | 4.5d | 2024-06-05 | 2024-06-11 | 1.04.04.25 FS-2.4d | 110.99d | 0d | CAPATAZ [17.29 h]; OPERARIO [34.58 h]; PEON [34.58 h] |
| 1.04.04.24 |  | CONCRETO f'c=280 kg/cm2 (buzones) | 0.5d | 2024-06-11 | 2024-06-12 | 1.04.04.26 FS+0.47d | 110.99d | 0d | CAPATAZ [0.24 h]; OPERARIO [4.84 h]; PEON [9.67 h]; OFICIAL [2.42 h] |
| 1.04.04.19 |  | RELLENO ESTRUCTURAL PARA OBRAS DE ARTE, CON MATERIAL PROPIO | 2.5d | 2024-06-11 | 2024-06-14 | 1.04.04.24 FS-0.1d | 110.99d |  | CAPATAZ [2.02 h]; CUADRADOR/VIGÍA [20.14 h]; PEON [40.28 h]; Rodillo Vib. Liso Autopropulsado 135 HP 12 TM [20.14 h]; Retroexcavador 58 HP [5.04 h] |

| ID | WBS | Activity | Duration | Start | Finish | Predecessors | Total float | Free float | Resources |
| --- | --- | --- | --- | --- | --- | --- | --- | --- | --- |
|  | 4 | **CANALES** |  | 2024-05-11 | 2024-06-28 |  |  |  |  |
| 1.04.04.30 |  | EXCAVACIÓN ESTRUCTURAL PARA CANALES | 8.5d | 2024-05-11 | 2024-05-21 | 1.04.04.18 FS+0.47d | 98.88d | 0d | CAPATAZ [14.03 h]; CUADRADOR/VIGÍA [140.34 h]; PEON [280.68 h]; Retroexcavador 58 HP [140.34 h] |
| 1.04.04.32 |  | CONCRETO f'c=100 kg/cm2 | 0.5d | 2024-05-22 | 2024-05-22 | 1.04.04.30 FS+0.47d | 98.88d | 0d | CAPATAZ [0.22 h]; OPERARIO [4.4 h]; PEON [8.79 h]; OFICIAL [2.2 h] |
| 1.04.04.34 |  | ENCOFRADO Y DESENCOFRADO RECTO | 17.5d | 2024-05-24 | 2024-06-13 | 1.04.04.32 FS+1.5d | 98.88d | 0d | CAPATAZ [427.09 h]; OPERARIO [854.31 h]; PEON [854.31 h] |
| 1.04.04.33 |  | CONCRETO f'c=280 kg/cm2 | 1.5d | 2024-06-15 | 2024-06-17 | 1.04.04.34 FS+1.5d | 98.88d | 0d | CAPATAZ [0.95 h]; OPERARIO [19.04 h]; PEON [38.06 h]; OFICIAL [9.52 h] |
| 1.04.04.36 |  | JUNTA WATER STOP SIN BULBO 150 mm | 0.5d | 2024-06-15 | 2024-06-15 | 1.04.04.33 FS-1.42d | 98.88d | 0d | OPERARIO [3.4 h] |
| 1.04.04.31 |  | RELLENO ESTRUCTURAL PARA OBRAS DE ARTE, CON MATERIAL PROPIO | 9.5d | 2024-06-18 | 2024-06-28 | 1.04.04.36 FS+1.42d | 98.88d |  | CAPATAZ [14.87 h]; CUADRADOR/VIGÍA [148.53 h]; PEON [297.01 h]; Rodillo Vib. Liso Autopropulsado 135 HP 12 TM [148.53 h]; Retroexcavador 58 HP [37.15 h] |
|  | 5 | **OBRAS DE DESCARGA** |  | 2024-05-22 | 2024-05-29 |  |  |  |  |
| 1.04.04.37 |  | EXCAVACIÓN ESTRUCTURAL PARA CANALES | 0.5d | 2024-05-22 | 2024-05-22 | 1.04.04.30 FS+0.47d | 125.32d | 0d | CAPATAZ [0.18 h]; CUADRADOR/VIGÍA [1.83 h]; PEON [3.66 h]; Retroexcavador 58 HP [1.83 h] |
| 1.04.04.39 |  | CONCRETO f'c=100 kg/cm2 | 0.5d | 2024-05-24 | 2024-05-24 | 1.04.04.37 FS+1.5d | 125.32d | 0d | CAPATAZ [0.01 h]; OPERARIO [0.1 h]; PEON [0.2 h]; OFICIAL [0.05 h] |
| 1.04.04.42 |  | ACERO DE REFUERZO fy=4200 kg/cm2 | 0.5d | 2024-05-25 | 2024-05-25 | 1.04.04.39 FS+0.47d | 125.32d | 0d | CAPATAZ [0.25 h]; OPERARIO [2.48 h]; PEON [2.48 h] |
| 1.04.04.41 |  | ENCOFRADO Y DESENCOFRADO RECTO | 0.5d | 2024-05-27 | 2024-05-27 | 1.04.04.42 FS+1d | 125.32d | 0d | CAPATAZ [3.98 h]; OPERARIO [7.95 h]; PEON [7.95 h] |
| 1.04.04.40 |  | CONCRETO f'c=280 kg/cm2 | 0.5d | 2024-05-28 | 2024-05-28 | 1.04.04.41 FS+0.47d | 125.32d | 0d | CAPATAZ [0.02 h]; OPERARIO [0.38 h]; PEON [0.75 h]; OFICIAL [0.19 h] |
| 1.04.04.43 |  | JUNTA WATER STOP SIN BULBO 150 mm | 0.5d | 2024-05-28 | 2024-05-29 | 1.04.04.40 FS-0.38d | 125.32d |  | OPERARIO [4.01 h] |
|  | 6 | **RETORNOS Q=100 A 1000 l/s** |  | 2024-04-22 | 2024-06-22 |  |  |  |  |
|  | 1 | **MOVIMIENTO DE TIERRAS** |  | 2024-04-22 | 2024-04-25 |  |  |  |  |
| 1.04.04.44 |  | CAMA DE ARENA | 3.5d | 2024-04-22 | 2024-04-25 | 1.04.04.02 FS+0.47d | 103.41d | 0d | CAPATAZ [8.2 h]; PEON [65.64 h] |
|  | 2 | **OBRAS DE CONCRETO** |  | 2024-04-22 | 2024-05-29 |  |  |  |  |
| 1.04.04.45 |  | CONCRETO F'C=100 Kg/cm2 | 0.5d | 2024-04-22 | 2024-04-22 | 1.04.04.49 FS-6.5d | 103.41d | 0d | CAPATAZ [0.35 h]; OPERARIO [6.94 h]; PEON [13.88 h]; OFICIAL [3.47 h] |
| 1.04.04.48 |  | ACERO DE REFUERZO Fy=4200 Kg/cm2 | 16.5d | 2024-04-23 | 2024-05-13 | 1.04.04.45 FS+0.47d | 103.41d | 0d | CAPATAZ [53.92 h]; OPERARIO [539.17 h]; PEON [539.17 h] |
| 1.04.04.47 |  | ENCOFRADO Y DESENCOFRADO RECTO | 11.5d | 2024-05-14 | 2024-05-27 | 1.04.04.48 FS+0.47d | 103.41d | 0d | CAPATAZ [176.38 h]; OPERARIO [352.82 h]; PEON [352.82 h] |
| 1.04.04.46 |  | CONCRETO F'C=280 Kg/cm2 | 1.5d | 2024-05-28 | 2024-05-29 | 1.04.04.47 FS+0.5d | 103.41d | 0d | CAPATAZ [0.95 h]; OPERARIO [19 h]; PEON [38 h]; OFICIAL [9.5 h] |
|  | 3 | **TUBERÍAS** |  | 2024-04-26 | 2024-04-29 |  |  |  |  |
| 1.04.04.49 |  | SUMINISTRO E INSTALACIÓN DE TUBERÍA HDPE DN600 mm | 2.5d | 2024-04-26 | 2024-04-29 | 1.04.04.44 FS+0.47d | 103.41d | 0d | CAPATAZ [1.66 h]; PEON [33.27 h]; Excavadora Sobre Oruga 260 HP [16.64 h]; OFICIAL [16.64 h] |

| ID | WBS | Activity | Duration | Start | Finish | Predecessors | Total float | Free float | Resources |
| --- | --- | --- | --- | --- | --- | --- | --- | --- | --- |
|  | 4 | **COMPUERTAS Y VÁLVULAS** |  | 2024-05-31 | 2024-06-22 |  |  |  |  |
| 1.04.04.50 |  | COMPUERTA TIPO CLAPETA DN600 mm | 19.5d | 2024-05-31 | 2024-06-22 | 1.04.04.46 FS+2d | 103.41d |  | CAPATAZ [16 h]; OPERARIO [160 h]; PEON [320 h] |
|  | 5 | **REPOSICIÓN DE CANALES** |  | 2024-04-22 | 2024-05-21 |  |  |  |  |
|  | 1 | **MOVIMIENTO DE TIERRAS** |  | 2024-04-22 | 2024-05-10 |  |  |  |  |
| 1.04.04.52 |  | EXCAVACIÓN EN TERRENO NATURAL CON EQUIPO | 2.5d | 2024-04-22 | 2024-04-24 | 1.04.04.51 FS-15.5d | 131.48d | 0d | CAPATAZ [2.07 h]; PEON [20.67 h]; Tractor S/Orugas (D6T) - 180 HP [20.67 h]; Excavadora Sobre Oruga 260 HP [20.67 h] |
| 1.04.04.51 |  | DEMOLICIÓN DE ESTRUCTURAS EXISTENTES | 14.5d | 2024-04-23 | 2024-05-10 | 1.04.04.02 FS+1.5d | 131.48d | 0d | CAPATAZ [22.99 h]; CUADRADOR/VIGÍA [229.48 h]; OPERARIO [458.87 h]; PEON [458.87 h]; Excavadora + Martillo hidraúlico [229.48 h] |
| 1.04.04.53 |  | RELLENO ESTRUCTURAL PARA OBRAS DE ARTE CON MATERIAL PROPIO | 2.5d | 2024-04-26 | 2024-04-29 | 1.04.04.52 FS+1.5d | 149.8d |  | CAPATAZ [1.61 h]; CUADRADOR/VIGÍA [16.05 h]; PEON [32.09 h]; Rodillo Vib. Liso Autopropulsado 135 HP 12 TM [16.05 h]; Retroexcavador 58 HP [4.01 h] |
|  | 2 | **OBRAS DE CONCRETO (CANAL 1** |  | 2024-04-26 | 2024-05-21 |  |  |  |  |
| 1.04.04.56 |  | CONCRETO f'c=100 kg/cm2 | 0.5d | 2024-04-26 | 2024-04-26 | 1.04.04.52 FS+1.5d | 131.48d | 0d | CAPATAZ [0.04 h]; OPERARIO [0.72 h]; PEON [1.45 h]; OFICIAL [0.36 h] |
| 1.04.04.55 |  | ACERO DE REFUERZO fy=4200 kg/cm2 | 5.5d | 2024-04-27 | 2024-05-04 | 1.04.04.56 FS+0.47d | 131.48d | 0d | CAPATAZ [16.51 h]; OPERARIO [165.09 h]; PEON [165.09 h] |
| 1.04.04.54 |  | ENCOFRADO Y DESENCOFRADO RECTO | 11.5d | 2024-05-06 | 2024-05-18 | 1.04.04.55 FS+0.47d | 131.48d | 0d | CAPATAZ [180.71 h]; OPERARIO [361.46 h]; PEON [361.46 h] |
| 1.04.04.57 |  | CONCRETO f'c=280 kg/cm2 | 0.5d | 2024-05-20 | 2024-05-20 | 1.04.04.54 FS+0.47d | 131.48d | 0d | CAPATAZ [0.25 h]; OPERARIO [4.96 h]; PEON [9.92 h]; OFICIAL [2.48 h] |
| 1.04.04.58 |  | JUNTA WATER STOP 6" | 1.5d | 2024-05-20 | 2024-05-21 | 1.04.04.57 FS-0.1d | 131.48d |  | OPERARIO [12.48 h] |
|  | 5 | **TRANSPORTE DE MATERIAL** |  | 2024-01-03 | 2024-08-17 |  |  |  |  |
| 1.04.04.61 |  | TRANSPORTE DE MATERIAL EXCEDENTE | 184.5d | 2024-01-03 | 2024-08-10 | 1.04.03.01 SS | 63.8d |  | Camión Volquete (15 m3) [107971 h]; CAPATAZ [9779.21 h]; CUADRADOR/VIGÍA [98764.7 h]; Excavadora Sobre Oruga 260 HP [3068.71 h] |
| 1.04.04.59 |  | TRANSPORTE DE MATERIAL GRANULAR | 184.5d | 2024-01-10 | 2024-08-17 | 1.04.03.42 SS-2.9d | 57.7d |  | CAPATAZ [458.84 h]; Excavadora Sobre Oruga 260 HP [319.67 h]; CUADRADOR/VIGÍA [4440.84 h]; Camión Volquete (15 m3) [4440.84 h] |
| 1.04.04.60 |  | TRANSPORTE DE ROCA | 170.5d | 2024-01-24 | 2024-08-15 | 1.04.03.59 SS-1.99d | 59.79d |  | CAPATAZ [1117.99 h]; CUADRADOR/VIGÍA [10087.1 h]; Excavadora Sobre Oruga 260 HP [1141.43 h]; Camión Volquete Roquero (15 m3) [13511.4 h] |
|  | 5 | **ARQUITECTURA Y PAISAJISMO** |  | 2024-08-03 | 2024-09-27 |  |  |  |  |
|  | 1 | **INTERVENCION PAISAJISMO - CRUCE PAMPA DURA** |  | 2024-08-03 | 2024-09-03 |  |  |  |  |
|  | 1 | **OBRAS PRELIMINARES** |  | 2024-08-03 | 2024-08-08 |  |  |  |  |
| 01.05.01 |  | MOVILIZACIÓN Y DEMOVILIZACIÓN DE EQUIPOS Y HERRAMIENTAS (ARQUITECTURA Y PAISAJISMO) | 4.5d | 2024-08-03 | 2024-08-08 | 01.05.02 SS-3.78d | 65.68d |  |  |
| 01.05.02 |  | TRAZO Y REPLANTEO PRELIMINAR | 0.5d | 2024-08-08 | 2024-08-08 | 1.04.03.79 FS+1.4d | 23.91d | 0d | OPERARIO [2.1 h]; PEON [4.19 h]; TOPOGRAFO [2.1 h] |
|  | 2 | **MOVIMIENTO DE TIERRAS** |  | 2024-08-10 | 2024-08-14 |  |  |  |  |
| 01.05.03 |  | EXCAVACIÓN MANUAL PARA INSTALACIÓN DE BORDILLOS Y CIMENTACIONES | 1.5d | 2024-08-10 | 2024-08-12 | 01.05.02 FS+1.5d | 23.91d | 0d | CAPATAZ [0.76 h]; PEON [10 h] |
| 01.05.04 |  | EXCAVACIÓN PARA MEJORAMIENTO DE SUELO CON TIERRA VEGETAL | 0.5d | 2024-08-13 | 2024-08-13 | 01.05.03 FS+0.5d | 23.91d | 0d | CAPATAZ [0.02 h]; PEON [0.24 h]; Excavadora Sobre Oruga 260 HP [0.24 h]; Tractor S/Orugas (D6T) - 180 HP [0.24 h] |
| 01.05.05 |  | ELIMINACION DE MATERIAL EXCEDENTE (DME´S) | 0.5d | 2024-08-14 | 2024-08-14 | 01.05.04 FS+0.5d | 23.91d | 0d | Camión Volquete (15 m3) [2.73 h]; CAPATAZ [0.45 h]; Excavadora Sobre Oruga 260 HP [0.91 h]; OPERARIO [0.91 h]; PEON [5.46 h]; Tractor S/Orugas (D6T) - 180 HP [0.91 h] |

| ID | WBS | Activity | Duration | Start | Finish | Predecessors | Total float | Free float | Resources |
| --- | --- | --- | --- | --- | --- | --- | --- | --- | --- |
|  | 3 | **PAVIMENTOS, RECUBRIMIENTOS Y BORDILLOS** |  | 2024-08-15 | 2024-08-26 |  |  |  |  |
| 01.05.06 |  | PISO DE GRAVILLA | 0.5d | 2024-08-15 | 2024-08-15 | 01.05.05 FS+0.5d | 23.91d | 0d | CAPATAZ [0.2 h]; OPERARIO [2 h]; PEON [3.99 h] |
| 01.05.07 |  | RECUBRIMIENTO DE PIEDRA DEL LUGAR e=0.05cm | 6.5d | 2024-08-16 | 2024-08-23 | 01.05.06 FS+0.5d | 23.91d | 0d | CAPATAZ [6 h]; OFICIAL [107.42 h]; PEON [107.42 h] |
| 01.05.08 |  | BORDILLOS DE PIEDRA DEL LUGAR | 1.5d | 2024-08-24 | 2024-08-26 | 01.05.07 FS+0.5d | 23.91d | 0d | CAPATAZ [1.53 h]; PEON [30.47 h] |
|  | 4 | **MOBILIARIOS, BARANDAS Y ESCALERAS** |  | 2024-08-24 | 2024-09-03 |  |  |  |  |
| 01.05.09 |  | ESCALERA DE CONCRETO SOBRE ENROCADO, CIMENTACION Y ANCLAJE | 1.5d | 2024-08-24 | 2024-08-26 | 01.05.08 FS-1.42d | 23.91d | 0d |  |
| 01.05.10 |  | BARANDA DE MADERA EUCALIPTO CON SOGA, INCLUYE CIMENTACIÓN | 1.5d | 2024-08-27 | 2024-08-28 | 01.05.09 FS+0.47d | 23.91d | 0d | CAPATAZ [0.36 h]; PEON [8 h] |
| 01.05.11 |  | TACHOS DE BASURA, INCLUYE CIMENTACIÓN | 0.5d | 2024-08-29 | 2024-08-29 | 01.05.10 FS+0.47d | 23.91d | 0d |  |
| 01.05.12 |  | BANCAS DE CONCRETO, INCLUYE CIMENTACIÓN | 0.5d | 2024-08-31 | 2024-08-31 | 01.05.11 FS+0.5d | 23.91d | 0d |  |
| 01.05.13 |  | POSTES DE ILUMINACIÓN, INCLUYE LUMINARIA Y CIMENTACIÓN | 1.5d | 2024-09-02 | 2024-09-03 | 01.05.12 FS+0.47d | 23.91d | 0d | CAPATAZ [2 h]; OPERARIO [2 h]; PEON [32 h] |
| 01.05.14 |  | SEÑALETICA INFORMATIVA | 0.5d | 2024-09-03 | 2024-09-03 | 01.05.13 FS-0.38d | 23.91d | 0d |  |
|  | 5 | **INTALACIÓN DE ALCORQUES** |  | 2024-09-03 | 2024-09-03 |  |  |  |  |
| 01.05.15 |  | ALCORQUES DE PIEDRA DE CANTO RODADO PARA ARBOLES | 0.5d | 2024-09-03 | 2024-09-03 | 01.05.14 FS-0.38d | 23.91d | 0d | CAPATAZ [0.02 h]; OFICIAL [1 h]; PEON [2 h] |
|  | 2 | **INTERVENCION PAISAJISMO - TANGAY** |  | 2024-08-31 | 2024-09-27 |  |  |  |  |
|  | 1 | **OBRAS PRELIMINARES** |  | 2024-08-31 | 2024-09-05 |  |  |  |  |
| 01.05.16 |  | MOVILIZACIÓN Y DEMOVILIZACIÓN DE EQUIPOS Y HERRAMIENTAS (ARQUITECTURA Y PAISAJISMO) | 4.5d | 2024-08-31 | 2024-09-05 | 01.05.15 FS-2.5d | 23.91d | 0d |  |
| 01.05.17 |  | TRAZO Y REPLANTEO PRELIMINAR | 0.5d | 2024-09-04 | 2024-09-04 | 01.05.16 FS-1.5d | 23.91d | 0d | OPERARIO [2 h]; PEON [3 h]; TOPOGRAFO [2 h] |
|  | 2 | **MOVIMIENTO DE TIERRAS** |  | 2024-09-05 | 2024-09-07 |  |  |  |  |
| 01.05.18 |  | EXCAVACIÓN MANUAL PARA INSTALACIÓN DE BORDILLOS Y CIMENTACIONES | 0.5d | 2024-09-05 | 2024-09-05 | 01.05.17 FS+0.47d | 23.91d | 0d | CAPATAZ [0.76 h]; PEON [6 h] |
| 01.05.19 |  | EXCAVACIÓN PARA MEJORAMIENTO DE SUELO CON TIERRA VEGETAL | 0.5d | 2024-09-06 | 2024-09-06 | 01.05.18 FS+0.47d | 23.91d | 0d | CAPATAZ; PEON; Excavadora Sobre Oruga 260 HP; Tractor S/Orugas (D6T) - 180 HP |
| 01.05.20 |  | ELIMINACION DE MATERIAL EXCEDENTE (DME´S) | 0.5d | 2024-09-07 | 2024-09-07 | 01.05.19 FS+0.47d | 23.91d | 0d | Camión Volquete (15 m3) [0.95 h]; CAPATAZ [0.12 h]; Excavadora Sobre Oruga 260 HP [0.32 h]; OPERARIO [0.25 h]; PEON [1.49 h]; Tractor S/Orugas (D6T) - 180 HP [0.32 h] |
|  | 3 | **PAVIMENTOS, RECUBRIMIENTOS Y BORDILLOS** |  | 2024-09-09 | 2024-09-16 |  |  |  |  |
| 01.05.21 |  | PISO DE GRAVILLA | 0.5d | 2024-09-09 | 2024-09-09 | 01.05.20 FS+0.47d | 23.91d | 0d | CAPATAZ [0.2 h]; OPERARIO [2 h]; PEON [3 h] |
| 01.05.22 |  | RECUBRIMIENTO DE PIEDRA DEL LUGAR e=0.05cm | 3.5d | 2024-09-10 | 2024-09-13 | 01.05.21 FS+0.5d | 23.91d | 0d | CAPATAZ [6 h]; OFICIAL [127.65 h]; PEON [127.65 h] |
| 01.05.23 |  | BORDILLOS DE PIEDRA DEL LUGAR | 1.5d | 2024-09-14 | 2024-09-16 | 01.05.22 FS+0.47d | 23.91d | 0d | CAPATAZ [1 h]; PEON [18 h] |

| ID | WBS | Activity | Duration | Start | Finish | Predecessors | Total float | Free float | Resources |
| --- | --- | --- | --- | --- | --- | --- | --- | --- | --- |
|  | 4 | **MOBILIARIOS, BARANDAS Y ESCALERAS** |  | 2024-09-18 | 2024-09-26 |  |  |  |  |
| 01.05.24 |  | ESCALERA DE CONCRETO SOBRE ENROCADO, CIMENTACION Y ANCLAJE | 1.5d | 2024-09-18 | 2024-09-19 | 01.05.23 FS+1.5d | 23.91d | 0d |  |
| 01.05.25 |  | BARANDA DE MADERA EUCALIPTO CON SOGA, INCLUYE CIMENTACIÓN | 0.5d | 2024-09-20 | 2024-09-20 | 01.05.24 FS+0.47d | 23.91d | 0d | CAPATAZ [0.36 h]; PEON [14.4 h] |
| 01.05.26 |  | TACHOS DE BASURA, INCLUYE CIMENTACIÓN | 0.5d | 2024-09-21 | 2024-09-21 | 01.05.25 FS+0.47d | 23.91d | 0d |  |
| 01.05.27 |  | BANCAS DE CONCRETO, INCLUYE CIMENTACIÓN | 0.5d | 2024-09-23 | 2024-09-23 | 01.05.26 FS+0.47d | 23.91d | 0d |  |
| 01.05.28 |  | POSTES DE ILUMINACIÓN, INCLUYE LUMINARIA Y CIMENTACIÓN | 1.5d | 2024-09-24 | 2024-09-25 | 01.05.27 FS+0.47d | 23.91d | 0d | CAPATAZ [2 h]; OPERARIO [2 h]; PEON [32 h] |
| 01.05.29 |  | SEÑALETICA INFORMATIVA | 0.5d | 2024-09-26 | 2024-09-26 | 01.05.28 FS+0.5d | 23.91d | 0d |  |
|  | 5 | **INTALACIÓN DE ALCORQUES** |  | 2024-09-27 | 2024-09-27 |  |  |  |  |
| 01.05.30 |  | ALCORQUES DE PIEDRA DE CANTO RODADO PARA ARBOLES | 0.5d | 2024-09-27 | 2024-09-27 | 01.05.29 FS+0.5d | 23.91d |  | CAPATAZ [0.02 h]; OFICIAL [0.6 h]; PEON [2 h] |
|  | 6 | **PROGRAMA DE CIERRE DE OBRA** |  | 2024-01-03 | 2024-10-26 |  |  |  |  |
| 01.06.02 |  | ACONDICIONAMIENTO DE DEPÓSITOS DE MATERIALES EXCEDENTES (DME) | 216.5d | 2024-01-03 | 2024-09-18 | 1.04.03.01 SS+0.2d | 31.6d |  | Camión Cisterna 4x2 400 HP Agua (5000 gal) [2020.44 h]; CAPATAZ [4102.1 h]; PEON [4102.1 h]; Tractor S/Orugas (D6T) - 180 HP [4102.1 h] |
| 01.06.05 |  | DESMOVILIZACIÓN | 6.4d | 2024-10-19 | 2024-10-26 | 01.06.04 FS-5d, L FF, M FF, N FF, O FF, P FF, 01.02.1 FF, 01.05.01 FF, 01.05.30 FF, 01.06.02 FF, 1.01.03 FF, 1.03.01.02 FF, 1.03.01.04 FF, 1.04.02.07 FF, 1.04.03.75 FF, 1.04.03.76 FF, 1.04.03.78 FF, 1.04.03.80 FF, 1.04.03.81 FF, 1.04.03.83 FF, 1.04.04.03 FF, 1.04.04.04 FF, 1.04.04.16 FF, 1.04.04.19 FF, 1.04.04.31 FF, 1.04.04.43 FF, 1.04.04.50 FF, 1.04.04.53 FF, 1.04.04.58 FF, 1.04.04.59 FF, 1.04.04.60 FF, 1.04.04.61 FF | 0d |  |  |
| 01.06.04 |  | RESTAURACIÓN DE ÁREAS DE INSTALACIONES PROVISIONALES | 4d | 2024-10-21 | 2024-10-25 | 1.04.03.82.21 FS+0.4d | 0d |  | CAPATAZ [6.7 h]; PEON [26.7 h]; Camión Cisterna 4x2 400 HP Agua (5000 gal) [6.7 h]; Rodillo Vib. Liso Autopropulsado 135 HP 12 TM [6.7 h] |
